# Planning and PD&E (EA)

Schedule from MS Project, 2016-08-01 to 2020-10-01.

## Calendars

- Standard: Mon-Fri 08:00-12:00, 13:00-17:00; Sat-Sun off.

## Schedule

| ID | WBS | Task | Type | Duration | Start | Finish | Predecessors | Total slack | Constraint | PSM Codes |
| --- | --- | --- | --- | --- | --- | --- | --- | --- | --- | --- |
| 1 | 1 | **PLANNING ACTIVITES** |  | 251d | 2016-08-01 | 2017-07-17 |  | 0d |  |  |
| 2 | 1.1 | District SWAT Planning Meeting (May take place 6 months to 5 years before SWAT Kickoff Meeting) | milestone | 1d | 2016-08-01 | 2016-08-01 |  | 0d | start no earlier than 2016-08-01 | 746 |
| 3 | 1.2 | District SWAT Strategy Meeting (6 months after the SWAT Planning Meeting when the Tentative Work Program has been submitted) |  | 2d | 2017-02-01 | 2017-02-02 | 2FS+131d | 0d |  |  |
| 4 | 1.3 | **ETDM PROGRAMMING SCREEN** |  | 97d | 2017-03-03 | 2017-07-17 |  | 0d |  |  |
| 5 | 1.3.1 | **ETDM Programming Screen Meeting** |  | 20d | 2017-03-03 | 2017-03-30 |  | 0d |  |  |
| 6 | 1.3.1.1 | ETDM Programming Screen PED |  | 20d | 2017-03-03 | 2017-03-30 | 3FS+20d | 0d |  |  |
| 7 | 1.3.1.2 | ETDM Programming Screen Purpose and Need |  | 20d | 2017-03-03 | 2017-03-30 | 3FS+20d | 0d |  |  |
| 8 | 1.3.1.3 | Planning Consistency Completion |  | 5d | 2017-03-03 | 2017-03-09 | 3FS+20d | 15d |  | 710 |
| 9 | 1.3.2 | ETDM PROGRAMMING SCREEN START/ADVANCE NOTIFICATION |  | 32d | 2017-03-31 | 2017-05-15 | 6, 7, 8 | 0d |  | 700, 224 |
| 10 | 1.3.3 | ETDM Programming Screen Responses |  | 44d | 2017-05-16 | 2017-07-14 | 9 | 0d |  |  |
| 11 | 1.3.4 | ETDM PROGRAMMING PRELIMINARY SUMMARY REPORT PUBLISHED |  | 1d | 2017-07-17 | 2017-07-17 | 10 | 0d |  | 701 |
| 12 | 2 | **PRE-PD&E ACTIVITIES** |  | 294d | 2017-08-01 | 2018-09-14 |  | 0d |  |  |
| 13 | 2.1 | SWAT Kickoff Meeting | milestone | 1d | 2017-08-01 | 2017-08-01 | 11FS+10d | 0d |  | 747 |
| 14 | 2.2 | Assign PD&E Project Manager |  | 1d | 2017-08-02 | 2017-08-02 | 13 | 0d |  | 704 |
| 15 | 2.3 | **Traffic Analysis** |  | 111d | 2017-08-03 | 2018-01-04 | 7 | 0d |  |  |
| 16 | 2.3.1 | Traffic Methodology Meeting |  | 1d | 2017-08-03 | 2017-08-03 | 7, 14, 13 | 0d |  |  |
| 17 | 2.3.2 | Traffic Methodology Memorandum |  | 5d | 2017-08-04 | 2017-08-10 | 16 | 0d |  |  |
| 18 | 2.3.3 | Traffic Data Collection |  | 20d | 2017-08-11 | 2017-09-07 | 17 | 0d |  |  |
| 19 | 2.3.4 | Crash Data and Analysis |  | 20d | 2017-08-11 | 2017-09-07 | 17 | 60d |  |  |
| 20 | 2.3.5 | Prepare Traffic Projections |  | 30d | 2017-09-08 | 2017-10-19 | 18 | 0d |  |  |
| 21 | 2.3.6 | Prepare Capacity Analysis |  | 30d | 2017-10-20 | 2017-11-30 | 20 | 0d |  |  |
| 22 | 2.3.7 | Draft Project Traffic Analysis Report |  | 10d | 2017-12-01 | 2017-12-14 | 21, 19 | 0d |  |  |
| 23 | 2.3.8 | FDOT Review - Draft Project Traffic Analysis Report |  | 10d | 2017-12-15 | 2017-12-28 | 22 | 0d |  |  |
| 24 | 2.3.9 | Final Project Traffic Analysis Report |  | 5d | 2017-12-29 | 2018-01-04 | 23 | 0d |  | 757 |

| ID | WBS | Task | Type | Duration | Start | Finish | Predecessors | Total slack | Free slack | Constraint | PSM Codes |
| --- | --- | --- | --- | --- | --- | --- | --- | --- | --- | --- | --- |
| 25 | 2.4 | **INTERCHANGE ACCESS REQUEST** |  | 292d | 2017-08-03 | 2018-09-14 |  | 74d |  |  |  |
| 26 | 2.4.1 | Initiate IJR/IMR/SIMR or IOAR |  | 1d | 2017-08-03 | 2017-08-03 | 9, 14 | 134d | 0d |  |  |
| 27 | 2.4.2 | Prepare MLOU |  | 5d | 2017-08-04 | 2017-08-10 | 26 | 134d | 0d |  |  |
| 28 | 2.4.3 | DIRC/SPO Review of MLOU |  | 10d | 2017-08-11 | 2017-08-24 | 27 | 134d | 0d |  |  |
| 29 | 2.4.4 | FHWA Review of MLOU |  | 20d | 2017-08-25 | 2017-09-21 | 28 | 134d | 60d |  |  |
| 30 | 2.4.5 | Develop Alternatives |  | 30d | 2017-12-15 | 2018-01-25 | 29, 22 | 74d | 0d |  |  |
| 31 | 2.4.6 | Perform Operational Analysis |  | 30d | 2018-01-26 | 2018-03-08 | 30 | 74d | 0d |  |  |
| 32 | 2.4.7 | Prepare Preliminary IMR/IJR |  | 45d | 2018-03-09 | 2018-05-10 | 31 | 74d | 0d |  |  |
| 33 | 2.4.8 | DIRC/SPO Reviw of Preliminary IJR/IMR |  | 10d | 2018-05-11 | 2018-05-24 | 32 | 74d | 0d |  |  |
| 34 | 2.4.9 | FHWA Review of Preliminary IJR/IMR |  | 20d | 2018-05-25 | 2018-06-21 | 33 | 74d | 0d |  |  |
| 35 | 2.4.10 | Prepare Final IJR/IMR |  | 30d | 2018-06-22 | 2018-08-02 | 34 | 74d | 0d |  |  |
| 36 | 2.4.11 | DIRC/SPO Review of Final IJR/IMR |  | 10d | 2018-08-03 | 2018-08-16 | 35 | 74d | 0d |  |  |
| 37 | 2.4.12 | FHWA Review of IJR/IMR |  | 20d | 2018-08-17 | 2018-09-13 | 36 | 74d | 0d |  |  |
| 38 | 2.4.13 | IJR/IMR Approval |  | 1d | 2018-09-14 | 2018-09-14 | 37 | 74d |  |  | 765 |
| 39 | 2.5 | **DEVELOP SCOPE AND SCHEDULE** |  | 21d | 2018-01-05 | 2018-02-02 |  | 0d |  |  |  |
| 40 | 2.5.1 | Begin PD&E Scope and Schedule |  | 20d | 2018-01-05 | 2018-02-01 | 11, 24 | 0d |  |  |  |
| 41 | 2.5.2 | PD&E SCOPE AND SCHEDULE COMPLETION |  | 1d | 2018-02-02 | 2018-02-02 | 40 | 0d |  |  | 703 |
| 42 | 2.6 | **PROCUREMENT** |  | 122d | 2018-02-05 | 2018-07-24 |  | 0d |  |  |  |
| 43 | 2.6.1 | PD&E Advertisement |  | 1d | 2018-02-05 | 2018-02-05 | 41 | 0d |  |  | 705 |
| 44 | 2.6.2 | Procurement |  | 120d | 2018-02-06 | 2018-07-23 | 41, 43 | 0d |  |  |  |
| 45 | 2.6.3 | Notice to Proceed | milestone | 1d | 2018-07-24 | 2018-07-24 | 44 | 0d |  | start no earlier than 2016-04-01 |  |
| 46 | 3 | **PD&E STUDY** |  | 572d | 2018-07-25 | 2020-10-01 |  | 0d |  |  |  |
| 47 | 3.1 | **PROJECT MANAGEMENT** |  | 7d | 2018-07-25 | 2018-08-02 |  | 0d |  |  |  |
| 48 | 3.1.1 | ENVIRONMENTAL ASSESSMENT START |  | 1d | 2018-07-25 | 2018-07-25 | 45 | 0d |  |  | 707 |
| 49 | 3.1.2 | Prepare Project Management Plan |  | 5d | 2018-07-26 | 2018-08-01 | 48 | 0d |  |  |  |
| 50 | 3.1.3 | Prepare QC Plan |  | 5d | 2018-07-26 | 2018-08-01 | 48 | 0d |  |  |  |
| 51 | 3.1.4 | Project Kickoff Meeting with FDOT |  | 1d | 2018-08-02 | 2018-08-02 | 49, 50 | 0d |  |  |  |

| ID | WBS | Task | Type | Duration | Start | Finish | Predecessors | Total slack | Free slack | PSM Codes |
| --- | --- | --- | --- | --- | --- | --- | --- | --- | --- | --- |
| 52 | 3.2 | **PUBLIC INVOLVEMENT** |  | 571d | 2018-07-26 | 2020-10-01 |  | 0d |  |  |
| 53 | 3.2.1 | Prepare Public Involvement Plan |  | 20d | 2018-07-26 | 2018-08-22 | 48 | 143d | 31d |  |
| 54 | 3.2.2 | Public Involvement Data Collection |  | 45d | 2018-08-03 | 2018-10-04 | 51 | 112d | 0d |  |
| 55 | 3.2.3 | **Prepare for Public Kickoff Meeting** |  | 47d | 2018-10-05 | 2018-12-10 |  | 112d |  | 365 |
| 56 | 3.2.3.1 | Site Review |  | 1d | 2018-10-05 | 2018-10-05 | 87FS-60d, 53, 54 | 112d | 0d |  |
| 57 | 3.2.3.2 | Newsletter |  | 20d | 2018-10-08 | 2018-11-02 | 56 | 112d | 0d |  |
| 58 | 3.2.3.3 | Newspaper Ad |  | 20d | 2018-10-08 | 2018-11-02 | 56 | 112d | 0d |  |
| 59 | 3.2.3.4 | Elected/Appointed/Property Owner Letters |  | 20d | 2018-10-08 | 2018-11-02 | 56 | 112d | 0d |  |
| 60 | 3.2.3.5 | Presentation/Display Material Review |  | 15d | 2018-11-05 | 2018-11-23 | 59, 57, 58 | 112d | 0d |  |
| 61 | 3.2.3.6 | Public Kickoff Meeting | milestone | 1d | 2018-11-26 | 2018-11-26 | 87, 82, 83, 84, 85, 89, 90, 60 | 112d | 0d |  |
| 62 | 3.2.3.7 | Public Comment Period |  | 10d | 2018-11-27 | 2018-12-10 | 61 | 112d | 83d |  |
| 63 | 3.2.4 | **Prepare for Public Information Meeting** |  | 76d | 2019-04-05 | 2019-07-19 |  | 0d |  | 365 |
| 64 | 3.2.4.1 | Site Review |  | 1d | 2019-04-05 | 2019-04-05 | 107FS-60d, 62 | 29d | 0d |  |
| 65 | 3.2.4.2 | Newsletter |  | 20d | 2019-04-08 | 2019-05-03 | 64 | 29d | 0d |  |
| 66 | 3.2.4.3 | Newspaper Ad |  | 20d | 2019-04-08 | 2019-05-03 | 64 | 29d | 0d |  |
| 67 | 3.2.4.4 | Elected/Appointed/Property Owner Letters |  | 20d | 2019-04-08 | 2019-05-03 | 64 | 29d | 0d |  |
| 68 | 3.2.4.5 | Presentation/Display Material Review |  | 15d | 2019-05-06 | 2019-05-24 | 64, 65, 66, 67 | 29d |  |  |
| 69 | 3.2.4.6 | Public Information Meeting | milestone | 1d | 2019-07-05 | 2019-07-05 | 107FS+5d, 68, 34 | 0d |  | 292 |
| 70 | 3.2.4.7 | Public Comment Period |  | 10d | 2019-07-08 | 2019-07-19 | 69 | 0d |  |  |
| 71 | 3.2.5 | **Prepare for Public Hearing** |  | 93d | 2020-05-26 | 2020-10-01 |  | 0d |  | 366 |
| 72 | 3.2.5.1 | Site Review |  | 20d | 2020-05-26 | 2020-06-22 | 70, 147 | 12d | 0d |  |
| 73 | 3.2.5.2 | Newsletter |  | 20d | 2020-06-23 | 2020-07-20 | 72 | 12d |  |  |
| 74 | 3.2.5.3 | Newspaper Ad |  | 20d | 2020-06-23 | 2020-07-20 | 72 | 12d |  |  |
| 75 | 3.2.5.4 | Elected/Appointed/Property Owner Letters |  | 20d | 2020-07-09 | 2020-08-05 | 72, 155 | 0d |  |  |
| 76 | 3.2.5.5 | Presentation/Display Material Review |  | 15d | 2020-08-06 | 2020-08-26 | 72, 73, 74, 75 | 0d |  |  |
| 77 | 3.2.5.6 | Notice of Public Availability |  | 15d | 2020-08-27 | 2020-09-16 | 76 | 0d |  |  |
| 78 | 3.2.5.7 | Public Hearing | milestone | 1d | 2020-09-17 | 2020-09-17 | 77, 76 | 0d |  | 262 |
| 79 | 3.2.5.8 | Public Comment Period |  | 10d | 2020-09-18 | 2020-10-01 | 78 | 0d |  |  |

| ID | WBS | Task | Duration | Start | Finish | Predecessors | Total slack | Free slack | PSM Codes |
| --- | --- | --- | --- | --- | --- | --- | --- | --- | --- |
| 80 | 3.3 | **ENGINEERING ANALYSIS** | 391d | 2018-08-03 | 2020-01-31 |  | 0d |  |  |
| 81 | 3.3.1 | **Data Collection** | 50d | 2018-08-03 | 2018-10-11 |  | 143d |  |  |
| 82 | 3.3.1.1 | Roadway Data Collection | 50d | 2018-08-03 | 2018-10-11 | 51 | 143d | 31d |  |
| 83 | 3.3.1.2 | Drainage Data Collection | 50d | 2018-08-03 | 2018-10-11 | 51 | 143d | 31d |  |
| 84 | 3.3.1.3 | Bridge Data Collection | 50d | 2018-08-03 | 2018-10-11 | 51 | 143d | 31d |  |
| 85 | 3.3.1.4 | Geotechnical Data Collection | 50d | 2018-08-03 | 2018-10-11 | 51 | 143d | 31d |  |
| 86 | 3.3.1.5 | Topographic Survey and ROW Mapping | 50d | 2018-08-03 | 2018-10-11 | 51 | 515d |  |  |
| 87 | 3.3.1.6 | Prepare Base Map | 50d | 2018-08-03 | 2018-10-11 | 51 | 143d | 31d |  |
| 88 | 3.3.2 | **Traffic Analysis** | 105d | 2018-08-03 | 2018-12-27 |  | 0d |  |  |
| 89 | 3.3.2.1 | Traffic Data Collection | 20d | 2018-08-03 | 2018-08-30 | 51 | 0d |  |  |
| 90 | 3.3.2.2 | Crash Data and Analysis | 20d | 2018-08-03 | 2018-08-30 | 51 | 173d | 61d |  |
| 91 | 3.3.2.3 | Prepare Traffic Projections | 30d | 2018-08-31 | 2018-10-11 | 89 | 0d |  |  |
| 92 | 3.3.2.4 | Prepare Capacity Analysis | 30d | 2018-10-12 | 2018-11-22 | 91 | 0d |  |  |
| 93 | 3.3.2.5 | Draft Project Traffic Analysis Report | 10d | 2018-11-23 | 2018-12-06 | 92 | 0d |  |  |
| 94 | 3.3.2.6 | FDOT Review - Draft Project Traffic Analysis Report | 10d | 2018-12-07 | 2018-12-20 | 93 | 0d |  |  |
| 95 | 3.3.2.7 | Final Project Traffic Analysis Report | 5d | 2018-12-21 | 2018-12-27 | 94 | 0d |  | 757 |
| 96 | 3.3.3 | **Alternative Analysis** | 301d | 2018-12-07 | 2020-01-31 |  | 15d |  |  |
| 97 | 3.3.3.1 | Typical Sections Analysis | 40d | 2018-12-07 | 2019-01-31 | 93 | 55d |  |  |
| 98 | 3.3.3.2 | Complete Streets/Multi Modal Analysis | 40d | 2018-12-07 | 2019-01-31 | 93 | 55d |  |  |
| 99 | 3.3.3.3 | Concept Development | 40d | 2018-12-28 | 2019-02-21 | 92, 95, 38 | 0d |  |  |
| 100 | 3.3.3.4 | Access Management Analysis | 40d | 2018-12-28 | 2019-02-21 | 95 | 40d |  |  |
| 101 | 3.3.3.5 | Drainage Analysis | 40d | 2019-02-22 | 2019-04-18 | 99 | 0d |  |  |
| 102 | 3.3.3.6 | Utility Coordination & Analysis | 40d | 2019-02-22 | 2019-04-18 | 99 | 0d |  |  |
| 103 | 3.3.3.7 | Railroad Coordination | 40d | 2019-02-22 | 2019-04-18 | 99 | 0d |  |  |
| 104 | 3.3.3.8 | Evaluation Matrix (1st Draft) | 5d | 2019-04-19 | 2019-04-25 | 97, 98, 101, 102, 103, 100, 99 | 0d |  |  |
| 105 | 3.3.3.9 | Construction Cost Estimates (LRE) | 10d | 2019-04-26 | 2019-05-09 | 104 | 30d |  |  |
| 106 | 3.3.3.10 | Right-of-Way Analysis | 20d | 2019-04-26 | 2019-05-23 | 104 | 20d |  |  |
| 107 | 3.3.3.11 | Evaluation Matrix (2nd Draft) | 5d | 2019-06-21 | 2019-06-27 | 105, 106, 119, 120, 121, 122, 123, 124 | 0d |  |  |
| 108 | 3.3.3.12 | Refine Alternatives (based on public input) | 20d | 2019-07-22 | 2019-08-16 | 70 | 294d |  |  |
| 109 | 3.3.3.13 | Prepare 1st DRAFT Engineering Reports (Drainage, Utility, Roadway Plans, ITS, Lighting, Pavement, Geotech, PER) | 30d | 2019-07-22 | 2019-08-30 | 70, 24, 95 | 0d |  |  |
| 110 | 3.3.3.14 | FDOT Review - 1st DRAFT Engineering Reports | 20d | 2019-09-02 | 2019-09-27 | 109 | 0d |  |  |
| 111 | 3.3.3.15 | Update DRAFT Engineering Reports | 15d | 2019-09-30 | 2019-10-18 | 110 | 0d |  |  |
| 112 | 3.3.3.16 | VE Study | 5d | 2019-10-21 | 2019-10-25 | 111 | 0d |  |  |
| 113 | 3.3.3.17 | VE Issues Resolution | 10d | 2019-11-25 | 2019-12-06 | 112FS+20d | 0d |  |  |
| 114 | 3.3.3.18 | Prepare Typical Section Package | 20d | 2019-12-09 | 2020-01-03 | 113 | 174d | 0d |  |
| 115 | 3.3.3.19 | Prepare Design Variations and Exceptions | 20d | 2019-12-09 | 2020-01-03 | 113 | 174d | 0d |  |
| 116 | 3.3.3.20 | Typical Section Selection | 20d | 2020-01-06 | 2020-01-31 | 114, 115 | 174d |  | 759 |
| 117 | 3.3.3.21 | FDOT Review - 2nd DRAFT Engineering Reports (Drainage, Utility, Roadway Plans, ITS, Lighting, Pavement, Geotech, PER) | 20d | 2020-01-06 | 2020-01-31 | 114 | 174d |  |  |

| ID | WBS | Task | Duration | Start | Finish | Predecessors | Total slack | Free slack | PSM Codes |
| --- | --- | --- | --- | --- | --- | --- | --- | --- | --- |
| 118 | 3.4 | **ENVIRONMENTAL ANALYSIS** | 182d | 2019-04-26 | 2020-01-06 |  | 0d |  |  |
| 119 | 3.4.1 | Data Collection & Cultural Resources Assessment Survey | 40d | 2019-04-26 | 2019-06-20 | 104 | 0d |  |  |
| 120 | 3.4.2 | Data Collection & Noise Analysis | 40d | 2019-04-26 | 2019-06-20 | 104 | 0d |  |  |
| 121 | 3.4.3 | Data Collection & Contamination Screen Evaluation | 40d | 2019-04-26 | 2019-06-20 | 104 | 0d |  |  |
| 122 | 3.4.4 | Wetland Delineation and Evaluation | 40d | 2019-04-26 | 2019-06-20 | 104 | 0d |  |  |
| 123 | 3.4.5 | Data Collection & Wildlife Survey | 40d | 2019-04-26 | 2019-06-20 | 104 | 0d |  |  |
| 124 | 3.4.6 | Essential Fish Habitat Evaluation | 40d | 2019-04-26 | 2019-06-20 | 104 | 0d |  |  |
| 125 | 3.4.7 | Determination of Section 4(f) | 15d | 2019-04-26 | 2019-05-16 | 104 | 71d | 0d |  |
| 126 | 3.4.8 | Prepare 1st Draft Natural Resource Evaluation Report | 30d | 2019-06-21 | 2019-08-01 | 122, 123, 124 | 46d | 0d |  |
| 127 | 3.4.9 | Prepare 1st Draft Cultural Resources Assessment Survey | 30d | 2019-06-21 | 2019-08-01 | 119 | 46d | 0d |  |
| 128 | 3.4.10 | Prepare 1st Draft Contamination Screen Evaluation Report | 30d | 2019-06-21 | 2019-08-01 | 121 | 46d | 0d |  |
| 129 | 3.4.11 | Prepare 1st Draft Noise Study Report | 30d | 2019-06-21 | 2019-08-01 | 120 | 46d | 0d |  |
| 130 | 3.4.12 | Prepare Draft Section 4(f) Evaluation | 30d | 2019-05-17 | 2019-06-27 | 125 | 71d | 25d |  |
| 131 | 3.4.13 | FDOT Review 1st DRAFT Environmental Reports (NRE, CSER, CRAS, Noise, Section 4(f)) | 20d | 2019-08-02 | 2019-08-29 | 126, 127, 128, 129, 130 | 46d | 0d |  |
| 132 | 3.4.14 | Update Environmental Reports | 15d | 2019-08-30 | 2019-09-19 | 131 | 46d | 0d |  |
| 133 | 3.4.15 | Finalize Cultural Resources Assessment Survey | 10d | 2019-09-20 | 2019-10-03 | 132 | 46d |  | 333 |
| 134 | 3.4.16 | Finalize Natural Resource Evaluation Report | 10d | 2019-09-20 | 2019-10-03 | 132 | 56d | 46d | 761 |
| 135 | 3.4.17 | Submit CRAS to OEM | 20d | 2019-12-09 | 2020-01-03 | 132, 113, 133 | 0d |  |  |
| 136 | 3.4.18 | SHPO Consultation Complete | 1d | 2020-01-06 | 2020-01-06 | 135 | 0d |  | 762 |
| 137 | 3.4.19 | Submit NRE to USFWS | 1d | 2019-12-09 | 2019-12-09 | 113, 134 | 10d | 0d |  |
| 138 | 3.4.20 | Submit NRE to NMFS | 1d | 2019-12-09 | 2019-12-09 | 113, 134 | 10d | 0d |  |
| 139 | 3.4.21 | Informal USFWS Consultation Complete | 10d | 2019-12-10 | 2019-12-23 | 137 | 10d |  | 752 |
| 140 | 3.4.22 | Informal NMFS Consultation Complete | 10d | 2019-12-10 | 2019-12-23 | 138 | 10d |  | 763 |
| 141 | 3.4.23 | Prepare Conceptual Relocation Plan | 20d | 2019-12-09 | 2020-01-03 | 113 | 1d |  |  |

| ID | WBS | Task | Type | Duration | Start | Finish | Predecessors | Total slack | Free slack | PSM Codes |
| --- | --- | --- | --- | --- | --- | --- | --- | --- | --- | --- |
| 142 | 3.5 | **FINAL ENVIRONMENTAL ASSESSMENT DOCUMENTS** |  | 169d | 2020-01-07 | 2020-08-28 |  | 0d |  |  |
| 143 | 3.5.1 | Prepare 1st DRAFT Environmental Assessment |  | 20d | 2020-01-07 | 2020-02-03 | 113, 11, 136, 139, 140, 141, 8 | 0d |  |  |
| 144 | 3.5.2 | District Review DRAFT Environmental Assessment |  | 20d | 2020-02-04 | 2020-03-02 | 143 | 0d |  | 713 |
| 145 | 3.5.3 | Prepare 2nd DRAFT Environmental Assessment |  | 20d | 2020-03-03 | 2020-03-30 | 144 | 0d |  |  |
| 146 | 3.5.4 | OEM Review of 2nd DRAFT Environmental Assessment |  | 20d | 2020-03-31 | 2020-04-27 | 145 | 0d |  |  |
| 147 | 3.5.5 | Prepare 3rd DRAFT Environmental Asssessment |  | 20d | 2020-04-28 | 2020-05-25 | 146 | 0d |  |  |
| 148 | 3.5.6 | District submit Environmental Assessment to Cooperating Agencies |  | 20d | 2020-05-26 | 2020-06-22 | 147 | 0d |  |  |
| 149 | 3.5.7 | Finalize Engineering & Environmental Reports |  | 10d | 2020-05-26 | 2020-06-08 | 147 | 10d |  |  |
| 150 | 3.5.8 | Finalize Section 4(f) Evaluation |  | 5d | 2020-05-26 | 2020-06-01 | 147 | 15d |  | 751 |
| 151 | 3.5.9 | Finalize Noise Study Report |  | 5d | 2020-05-26 | 2020-06-01 | 147 | 15d |  | 335 |
| 152 | 3.5.10 | Finalize Preliminary Engineering Report |  | 5d | 2020-05-26 | 2020-06-01 | 147 | 15d |  | 760 |
| 153 | 3.5.11 | Prepare FINAL Environmental Assessment |  | 10d | 2020-06-23 | 2020-07-06 | 150, 151, 148, 149, 152 | 0d |  |  |
| 154 | 3.5.12 | FINAL Envrionmental Assessment to OEM |  | 1d | 2020-07-07 | 2020-07-07 | 153 | 0d |  | 718 |
| 155 | 3.5.13 | Environmental Assessment Approved by OEM |  | 1d | 2020-07-08 | 2020-07-08 | 154 | 0d |  | 719 |
| 156 | 3.5.14 | Prepare DRAFT FONSI |  | 5d | 2020-07-09 | 2020-07-15 | 155 | 24d | 0d |  |
| 157 | 3.5.15 | District Review DRAFT FONSI |  | 5d | 2020-07-16 | 2020-07-22 | 156 | 24d | 0d |  |
| 158 | 3.5.16 | Prepare 2nd DRAFT FONSI |  | 5d | 2020-07-23 | 2020-07-29 | 157 | 24d | 0d |  |
| 159 | 3.5.17 | OEM Review 2nd DRAFT FONSI |  | 5d | 2020-07-30 | 2020-08-05 | 158 | 24d | 0d |  |
| 160 | 3.5.18 | Prepare FINAL FONSI |  | 5d | 2020-08-06 | 2020-08-12 | 159 | 24d | 0d |  |
| 161 | 3.5.19 | OEM Approves FONSI |  | 1d | 2020-08-13 | 2020-08-13 | 160 | 34d | 0d | 732 |
| 162 | 3.5.20 | EA and FONSI uploaded to ETDM |  | 1d | 2020-08-14 | 2020-08-14 | 161 | 34d |  |  |
| 163 | 3.5.21 | Location Design Concept Acceptance | milestone | 1d | 2020-08-13 | 2020-08-13 | 160 | 24d | 0d | 263 |
| 164 | 3.5.22 | Publish Notification of EA/FONSI Approval |  | 1d | 2020-08-14 | 2020-08-14 | 163 | 33d | 9d | 736 |
| 165 | 3.5.23 | Pass the Torch Meeting |  | 1d | 2020-08-28 | 2020-08-28 | 163FS+10d, 164 | 24d |  |  |
