# Planning and PD&E (EIS)

Schedule from MS Project, 2016-08-01 to 2021-10-26.

## Calendars

- Standard: Mon-Fri 08:00-12:00, 13:00-17:00; Sat-Sun off.

## Schedule

| ID | WBS | Task | Type | Duration | Start | Finish | Predecessors | Total slack | Constraint | PSM Codes |
| --- | --- | --- | --- | --- | --- | --- | --- | --- | --- | --- |
| 1 | 1 | **PLANNING ACTIVITES** |  | 251d | 2016-08-01 | 2017-07-17 |  | 0d |  |  |
| 2 | 1.1 | District SWAT Planning Meeting (May take place 6 months to 5 years before SWAT Kickoff Meeting) | milestone | 1d | 2016-08-01 | 2016-08-01 |  | 0d | start no earlier than 2016-08-01 | 746 |
| 3 | 1.2 | District SWAT Strategy Meeting (6 months after the SWAT Planning Meeting when the Tentative Work Program has been submitted) | milestone | 2d | 2017-02-01 | 2017-02-02 | 2FS+131d | 0d |  |  |
| 4 | 1.3 | **ETDM PROGRAMMING SCREEN** |  | 97d | 2017-03-03 | 2017-07-17 |  | 0d |  |  |
| 5 | 1.3.1 | **ETDM Programming Screen Meeting** |  | 20d | 2017-03-03 | 2017-03-30 |  | 0d |  |  |
| 6 | 1.3.1.1 | ETDM Programming Screen PED |  | 20d | 2017-03-03 | 2017-03-30 | 3FS+20d | 0d |  |  |
| 7 | 1.3.1.2 | ETDM Programming Screen Purpose and Need |  | 20d | 2017-03-03 | 2017-03-30 | 3FS+20d | 0d |  |  |
| 8 | 1.3.1.3 | Planning Consistency Completion |  | 5d | 2017-03-03 | 2017-03-09 | 3FS+20d | 15d |  | 710 |
| 9 | 1.3.2 | ETDM PROGRAMMING SCREEN START/ADVANCE NOTIFICATION |  | 32d | 2017-03-31 | 2017-05-15 | 6, 7, 8 | 0d |  | 700, 224 |
| 10 | 1.3.3 | ETDM Programming Screen Responses |  | 44d | 2017-05-16 | 2017-07-14 | 9 | 0d |  |  |
| 11 | 1.3.4 | ETDM PROGRAMMING PRELIMINARY SUMMARY REPORT PUBLISHED |  | 1d | 2017-07-17 | 2017-07-17 | 10 | 0d |  | 701 |
| 12 | 2 | **PRE-PD&E ACTIVITIES** |  | 294d | 2017-08-01 | 2018-09-14 |  | 0d |  |  |
| 13 | 2.1 | SWAT Kickoff Meeting | milestone | 1d | 2017-08-01 | 2017-08-01 | 11FS+10d | 0d |  | 747 |
| 14 | 2.2 | Assign PD&E Project Manager |  | 1d | 2017-08-02 | 2017-08-02 | 13 | 0d |  | 704 |
| 15 | 2.3 | **Traffic Analysis** |  | 111d | 2017-08-03 | 2018-01-04 | 7 | 0d |  |  |
| 16 | 2.3.1 | Traffic Methodology Meeting |  | 1d | 2017-08-03 | 2017-08-03 | 7, 14, 13 | 0d |  |  |
| 17 | 2.3.2 | Traffic Methodology Memorandum |  | 5d | 2017-08-04 | 2017-08-10 | 16 | 0d |  |  |
| 18 | 2.3.3 | Traffic Data Collection |  | 20d | 2017-08-11 | 2017-09-07 | 17 | 0d |  |  |
| 19 | 2.3.4 | Crash Data and Analysis |  | 20d | 2017-08-11 | 2017-09-07 | 17 | 60d |  |  |
| 20 | 2.3.5 | Prepare Traffic Projections |  | 30d | 2017-09-08 | 2017-10-19 | 18 | 0d |  |  |
| 21 | 2.3.6 | Prepare Capacity Analysis |  | 30d | 2017-10-20 | 2017-11-30 | 20 | 0d |  |  |
| 22 | 2.3.7 | Draft Project Traffic Analysis Report |  | 10d | 2017-12-01 | 2017-12-14 | 21, 19 | 0d |  |  |
| 23 | 2.3.8 | FDOT Review - Draft Project Traffic Analysis Report |  | 10d | 2017-12-15 | 2017-12-28 | 22 | 0d |  |  |
| 24 | 2.3.9 | Final Project Traffic Analysis Report |  | 5d | 2017-12-29 | 2018-01-04 | 23 | 0d |  | 757 |

| ID | WBS | Task | Type | Duration | Start | Finish | Predecessors | Total slack | Free slack | Constraint | PSM Codes |
| --- | --- | --- | --- | --- | --- | --- | --- | --- | --- | --- | --- |
| 25 | 2.4 | **INTERCHANGE ACCESS REQUEST** |  | 292d | 2017-08-03 | 2018-09-14 |  | 72d |  |  |  |
| 26 | 2.4.1 | Initiate IJR/IMR/SIMR or IOAR |  | 1d | 2017-08-03 | 2017-08-03 | 9, 14 | 132d | 0d |  |  |
| 27 | 2.4.2 | Prepare MLOU |  | 5d | 2017-08-04 | 2017-08-10 | 26 | 132d | 0d |  |  |
| 28 | 2.4.3 | DIRC/SPO Review of MLOU |  | 10d | 2017-08-11 | 2017-08-24 | 27 | 132d | 0d |  |  |
| 29 | 2.4.4 | FHWA Review of MLOU |  | 20d | 2017-08-25 | 2017-09-21 | 28 | 132d | 60d |  |  |
| 30 | 2.4.5 | Develop Alternatives |  | 30d | 2017-12-15 | 2018-01-25 | 29, 22 | 72d | 0d |  |  |
| 31 | 2.4.6 | Perform Operational Analysis |  | 30d | 2018-01-26 | 2018-03-08 | 30 | 72d | 0d |  |  |
| 32 | 2.4.7 | Prepare Preliminary IMR/IJR |  | 45d | 2018-03-09 | 2018-05-10 | 31 | 72d | 0d |  |  |
| 33 | 2.4.8 | DIRC/SPO Reviw of Preliminary IJR/IMR |  | 10d | 2018-05-11 | 2018-05-24 | 32 | 72d | 0d |  |  |
| 34 | 2.4.9 | FHWA Review of Preliminary IJR/IMR |  | 20d | 2018-05-25 | 2018-06-21 | 33 | 72d | 0d |  |  |
| 35 | 2.4.10 | Prepare Final IJR/IMR |  | 30d | 2018-06-22 | 2018-08-02 | 34 | 72d | 0d |  |  |
| 36 | 2.4.11 | DIRC/SPO Review of Final IJR/IMR |  | 10d | 2018-08-03 | 2018-08-16 | 35 | 72d | 0d |  |  |
| 37 | 2.4.12 | FHWA Review of IJR/IMR |  | 20d | 2018-08-17 | 2018-09-13 | 36 | 72d | 0d |  |  |
| 38 | 2.4.13 | IJR/IMR Approval |  | 1d | 2018-09-14 | 2018-09-14 | 37 | 72d |  |  | 765 |
| 39 | 2.5 | **DEVELOP SCOPE AND SCHEDULE** |  | 21d | 2018-01-05 | 2018-02-02 |  | 0d |  |  |  |
| 40 | 2.5.1 | Begin PD&E Scope and Schedule |  | 20d | 2018-01-05 | 2018-02-01 | 11, 24 | 0d |  |  |  |
| 41 | 2.5.2 | PD&E SCOPE AND SCHEDULE COMPLETION |  | 1d | 2018-02-02 | 2018-02-02 | 40 | 0d |  |  | 703 |
| 42 | 2.6 | **PROCUREMENT** |  | 122d | 2018-02-05 | 2018-07-24 |  | 0d |  |  |  |
| 43 | 2.6.1 | PD&E Advertisement |  | 1d | 2018-02-05 | 2018-02-05 | 41 | 0d |  |  | 705 |
| 44 | 2.6.2 | Procurement |  | 120d | 2018-02-06 | 2018-07-23 | 41, 43 | 0d |  |  |  |
| 45 | 2.6.3 | Notice to Proceed | milestone | 1d | 2018-07-24 | 2018-07-24 | 44 | 850d |  | start no earlier than 2016-04-01 |  |
| 46 | 3 | **PD&E STUDY** |  | 1367d? | 2016-08-01 | 2021-10-26 |  | 0d |  |  |  |
| 47 | 3.1 | **PROJECT MANAGEMENT** |  | 22d | 2018-07-24 | 2018-08-22 |  | 0d |  |  |  |
| 48 | 3.1.1 | Prepare Project Management Plan |  | 5d | 2018-07-24 | 2018-07-30 | 44 | 0d |  |  |  |
| 49 | 3.1.2 | Prepare QC Plan |  | 5d | 2018-07-24 | 2018-07-30 | 44 | 0d |  |  |  |
| 50 | 3.1.3 | Project Kickoff Meeting with FDOT |  | 1d | 2018-07-31 | 2018-07-31 | 48, 49 | 0d |  |  |  |
| 51 | 3.1.4 | Prepare Draft Notice of Intent |  | 5d | 2018-08-01 | 2018-08-07 | 50 | 395d | 0d |  |  |
| 52 | 3.1.5 | District Review of Notice of Intent |  | 5d | 2018-08-08 | 2018-08-14 | 51 | 395d | 0d |  |  |
| 53 | 3.1.6 | OEM Review of Notice of Intent |  | 5d | 2018-08-15 | 2018-08-21 | 52 | 395d | 0d |  | 723 |
| 54 | 3.1.7 | Publish Notice of Intent in Federal Register |  | 1d | 2018-08-22 | 2018-08-22 | 53 | 395d |  |  | 708 |

| ID | WBS | Task | Type | Duration | Start | Finish | Predecessors | Total slack | Free slack | PSM Codes |
| --- | --- | --- | --- | --- | --- | --- | --- | --- | --- | --- |
| 55 | 3.2 | **PUBLIC INVOLVEMENT** |  | 1256d | 2016-08-01 | 2021-05-24 |  | 0d |  |  |
| 56 | 3.2.1 | Prepare Public Involvement Plan |  | 20d | 2016-08-01 | 2016-08-26 |  | 644d | 547d |  |
| 57 | 3.2.2 | Public Involvement Data Collection |  | 45d | 2018-08-01 | 2018-10-02 | 50 | 97d | 0d |  |
| 58 | 3.2.3 | Scoping Meeting |  | 1d | 2018-10-03 | 2018-10-03 | 56, 57 | 97d | 0d |  |
| 59 | 3.2.4 | **Prepare for Public Kickoff Meeting** |  | 66d | 2018-10-03 | 2019-01-02 |  | 93d |  | 365 |
| 60 | 3.2.4.1 | Site Review |  | 1d | 2018-10-03 | 2018-10-03 | 91FS-60d, 56, 57 | 112d | 0d |  |
| 61 | 3.2.4.2 | Newsletter |  | 20d | 2018-10-04 | 2018-10-31 | 60 | 112d | 0d |  |
| 62 | 3.2.4.3 | Newspaper Ad |  | 20d | 2018-10-04 | 2018-10-31 | 60 | 112d | 0d |  |
| 63 | 3.2.4.4 | Elected/Appointed/Property Owner Letters |  | 20d | 2018-10-04 | 2018-10-31 | 60 | 112d | 0d |  |
| 64 | 3.2.4.5 | Presentation/Display Material Review |  | 15d | 2018-11-01 | 2018-11-21 | 63, 61, 62 | 112d | 19d |  |
| 65 | 3.2.4.6 | Public Kickoff Meeting | milestone | 1d | 2018-12-19 | 2018-12-19 | 91, 86, 87, 88, 89, 93, 94, 64 | 93d | 0d |  |
| 66 | 3.2.4.7 | Public Comment Period |  | 10d | 2018-12-20 | 2019-01-02 | 65 | 93d | 64d |  |
| 67 | 3.2.5 | **Prepare for Public Information Meeting** |  | 76d | 2019-04-03 | 2019-07-17 |  | 0d |  | 365 |
| 68 | 3.2.5.1 | Site Review |  | 1d | 2019-04-03 | 2019-04-03 | 111FS-60d, 66 | 29d | 0d |  |
| 69 | 3.2.5.2 | Newsletter |  | 20d | 2019-04-04 | 2019-05-01 | 68 | 29d | 0d |  |
| 70 | 3.2.5.3 | Newspaper Ad |  | 20d | 2019-04-04 | 2019-05-01 | 68 | 29d | 0d |  |
| 71 | 3.2.5.4 | Elected/Appointed/Property Owner Letters |  | 20d | 2019-04-04 | 2019-05-01 | 68 | 29d | 0d |  |
| 72 | 3.2.5.5 | Presentation/Display Material Review |  | 15d | 2019-05-02 | 2019-05-22 | 68, 69, 70, 71 | 29d |  |  |
| 73 | 3.2.5.6 | Public Information Meeting | milestone | 1d | 2019-07-03 | 2019-07-03 | 111FS+5d, 72, 34 | 0d |  | 292 |
| 74 | 3.2.5.7 | Public Comment Period |  | 10d | 2019-07-04 | 2019-07-17 | 73 | 0d |  |  |
| 75 | 3.2.6 | **Prepare for Public Hearing** |  | 81d | 2021-02-01 | 2021-05-24 |  | 0d |  | 366 |
| 76 | 3.2.6.1 | Site Review |  | 20d | 2021-02-01 | 2021-02-26 | 158 | 0d |  |  |
| 77 | 3.2.6.2 | Newsletter |  | 20d | 2021-03-01 | 2021-03-26 | 76 | 0d |  |  |
| 78 | 3.2.6.3 | Newspaper Ad |  | 20d | 2021-03-01 | 2021-03-26 | 76 | 0d |  |  |
| 79 | 3.2.6.4 | Elected/Appointed/Property Owner Letters |  | 20d | 2021-03-01 | 2021-03-26 | 76 | 0d |  |  |
| 80 | 3.2.6.5 | Presentation/Display Material Review |  | 15d | 2021-03-29 | 2021-04-16 | 76, 77, 78, 79 | 0d |  |  |
| 81 | 3.2.6.6 | Notice of Public Availability |  | 15d | 2021-04-19 | 2021-05-07 | 80 | 0d |  |  |
| 82 | 3.2.6.7 | Public Hearing | milestone | 1d | 2021-05-10 | 2021-05-10 | 81, 80, 162 | 0d |  | 262 |
| 83 | 3.2.6.8 | Public Comment Period |  | 10d | 2021-05-11 | 2021-05-24 | 82 | 0d |  |  |

| ID | WBS | Task | Duration | Start | Finish | Predecessors | Total slack | Free slack | PSM Codes |
| --- | --- | --- | --- | --- | --- | --- | --- | --- | --- |
| 84 | 3.3 | **ENGINEERING ANALYSIS** | 411d | 2018-08-01 | 2020-02-26 |  | 0d |  |  |
| 85 | 3.3.1 | **Data Collection** | 100d | 2018-08-01 | 2018-12-18 |  | 93d |  |  |
| 86 | 3.3.1.1 | Roadway Data Collection | 50d | 2018-10-04 | 2018-12-12 | 50, 58 | 97d | 4d |  |
| 87 | 3.3.1.2 | Drainage Data Collection | 50d | 2018-10-04 | 2018-12-12 | 50, 58 | 97d | 4d |  |
| 88 | 3.3.1.3 | Bridge Data Collection | 50d | 2018-10-04 | 2018-12-12 | 50, 58 | 97d | 4d |  |
| 89 | 3.3.1.4 | Geotechnical Data Collection | 50d | 2018-08-01 | 2018-10-09 | 50 | 143d | 50d |  |
| 90 | 3.3.1.5 | Topographic Survey and ROW Mapping | 50d | 2018-08-01 | 2018-10-09 | 50 | 93d | 0d |  |
| 91 | 3.3.1.6 | Prepare Base Map | 50d | 2018-10-10 | 2018-12-18 | 50, 90 | 93d | 0d |  |
| 92 | 3.3.2 | **Traffic Analysis** | 105d | 2018-08-01 | 2018-12-25 |  | 0d |  |  |
| 93 | 3.3.2.1 | Traffic Data Collection | 20d | 2018-08-01 | 2018-08-28 | 50 | 0d |  |  |
| 94 | 3.3.2.2 | Crash Data and Analysis | 20d | 2018-08-01 | 2018-08-28 | 50 | 173d | 80d |  |
| 95 | 3.3.2.3 | Prepare Traffic Projections | 30d | 2018-08-29 | 2018-10-09 | 93 | 0d |  |  |
| 96 | 3.3.2.4 | Prepare Capacity Analysis | 30d | 2018-10-10 | 2018-11-20 | 95 | 0d |  |  |
| 97 | 3.3.2.5 | Draft Project Traffic Analysis Report | 10d | 2018-11-21 | 2018-12-04 | 96 | 0d |  |  |
| 98 | 3.3.2.6 | FDOT Review - Draft Project Traffic Analysis Report | 10d | 2018-12-05 | 2018-12-18 | 97 | 0d |  |  |
| 99 | 3.3.2.7 | Final Project Traffic Analysis Report | 5d | 2018-12-19 | 2018-12-25 | 98 | 0d |  | 757 |
| 100 | 3.3.3 | **Alternative Analysis** | 321d | 2018-12-05 | 2020-02-26 |  | 15d |  |  |
| 101 | 3.3.3.1 | Typical Sections Analysis | 40d | 2018-12-05 | 2019-01-29 | 97 | 55d |  |  |
| 102 | 3.3.3.2 | Complete Streets/Multi Modal Analysis | 40d | 2018-12-05 | 2019-01-29 | 97 | 55d |  |  |
| 103 | 3.3.3.3 | Concept Development | 40d | 2018-12-26 | 2019-02-19 | 96, 99, 38 | 0d |  |  |
| 104 | 3.3.3.4 | Access Management Analysis | 40d | 2018-12-26 | 2019-02-19 | 99 | 40d |  |  |
| 105 | 3.3.3.5 | Drainage Analysis | 40d | 2019-02-20 | 2019-04-16 | 103 | 0d |  |  |
| 106 | 3.3.3.6 | Utility Coordination & Analysis | 40d | 2019-02-20 | 2019-04-16 | 103 | 0d |  |  |
| 107 | 3.3.3.7 | Railroad Coordination | 40d | 2019-02-20 | 2019-04-16 | 103 | 0d |  |  |
| 108 | 3.3.3.8 | Evaluation Matrix (1st Draft) | 5d | 2019-04-17 | 2019-04-23 | 101, 102, 105, 106, 107, 104, 103 | 0d |  |  |
| 109 | 3.3.3.9 | Construction Cost Estimates (LRE) | 10d | 2019-04-24 | 2019-05-07 | 108 | 30d |  |  |
| 110 | 3.3.3.10 | Right-of-Way Analysis | 20d | 2019-04-24 | 2019-05-21 | 108 | 20d |  |  |
| 111 | 3.3.3.11 | Evaluation Matrix (2nd Draft) | 5d | 2019-06-19 | 2019-06-25 | 109, 110, 123, 124, 125, 126, 127, 128 | 0d |  |  |
| 112 | 3.3.3.12 | Refine Alternatives (based on public input) | 20d | 2019-07-18 | 2019-08-14 | 74 | 574d |  |  |
| 113 | 3.3.3.13 | Prepare 1st DRAFT Engineering Reports (Drainage, Utility, Roadway Plans, ITS, Lighting, Pavement, Geotech, PER) | 30d | 2019-07-18 | 2019-08-28 | 74, 24, 99 | 0d |  |  |
| 114 | 3.3.3.14 | FDOT Review - 1st DRAFT Engineering Reports | 20d | 2019-08-29 | 2019-09-25 | 113 | 0d |  |  |
| 115 | 3.3.3.15 | Update DRAFT Engineering Reports | 15d | 2019-09-26 | 2019-10-16 | 114 | 0d |  |  |
| 116 | 3.3.3.16 | VE Study | 5d | 2019-10-17 | 2019-10-23 | 115 | 0d |  |  |
| 117 | 3.3.3.17 | VE Issues Resolution | 10d | 2019-11-21 | 2019-12-04 | 116FS+20d | 0d |  |  |
| 118 | 3.3.3.18 | Prepare Typical Section Package | 20d | 2019-12-05 | 2020-01-01 | 117 | 0d |  |  |
| 119 | 3.3.3.19 | Prepare Design Variations and Exceptions | 20d | 2019-12-05 | 2020-01-01 | 117 | 0d |  |  |
| 120 | 3.3.3.20 | Typical Section Selection | 20d | 2020-01-02 | 2020-01-29 | 118, 119 | 0d |  | 759 |
| 121 | 3.3.3.21 | FDOT Review - 2nd DRAFT Engineering Reports (Drainage, Utility, Roadway Plans, ITS, Lighting, Pavement, Geotech, PER) | 20d | 2020-01-30 | 2020-02-26 | 118, 120 | 0d |  |  |

| ID | WBS | Task | Duration | Start | Finish | Predecessors | Total slack | Free slack | PSM Codes |
| --- | --- | --- | --- | --- | --- | --- | --- | --- | --- |
| 122 | 3.4 | **ENVIRONMENTAL ANALYSIS** | 182d | 2019-04-24 | 2020-01-02 |  | 0d |  |  |
| 123 | 3.4.1 | Data Collection & Cultural Resources Assessment Survey | 40d | 2019-04-24 | 2019-06-18 | 108, 58 | 0d |  |  |
| 124 | 3.4.2 | Data Collection & Noise Analysis | 40d | 2019-04-24 | 2019-06-18 | 108, 58 | 0d |  |  |
| 125 | 3.4.3 | Data Collection & Contamination Screen Evaluation | 40d | 2019-04-24 | 2019-06-18 | 108, 58 | 0d |  |  |
| 126 | 3.4.4 | Wetland Delineation and Evaluation | 40d | 2019-04-24 | 2019-06-18 | 108, 58 | 0d |  |  |
| 127 | 3.4.5 | Data Collection & Wildlife Survey | 40d | 2019-04-24 | 2019-06-18 | 108, 58 | 0d |  |  |
| 128 | 3.4.6 | Essential Fish Habitat Evaluation | 40d | 2019-04-24 | 2019-06-18 | 108, 58 | 0d |  |  |
| 129 | 3.4.7 | Determination of Section 4(f) | 15d | 2019-04-24 | 2019-05-14 | 108 | 110d | 0d |  |
| 130 | 3.4.8 | Prepare 1st Draft Natural Resource Evaluation Report | 30d | 2019-06-19 | 2019-07-30 | 126, 127, 128 | 85d | 0d |  |
| 131 | 3.4.9 | Prepare 1st Draft Cultural Resources Assessment Survey | 30d | 2019-06-19 | 2019-07-30 | 123 | 85d | 0d |  |
| 132 | 3.4.10 | Prepare 1st Draft Contamination Screen Evaluation Report | 30d | 2019-06-19 | 2019-07-30 | 125 | 85d | 0d |  |
| 133 | 3.4.11 | Prepare 1st Draft Noise Study Report | 30d | 2019-06-19 | 2019-07-30 | 124 | 85d | 0d |  |
| 134 | 3.4.12 | Prepare Draft Section 4(f) Evaluation | 30d | 2019-05-15 | 2019-06-25 | 129 | 110d | 25d |  |
| 135 | 3.4.13 | FDOT Review 1st DRAFT Environmental Reports (NRE, CSER, CRAS, Noise, Section 4(f)) | 20d | 2019-07-31 | 2019-08-27 | 130, 131, 132, 133, 134 | 85d | 0d |  |
| 136 | 3.4.14 | Update Environmental Reports | 15d | 2019-08-28 | 2019-09-17 | 135 | 85d | 0d |  |
| 137 | 3.4.15 | Finalize Cultural Resources Assessment Survey | 10d | 2019-09-18 | 2019-10-01 | 136 | 85d | 46d | 333 |
| 138 | 3.4.16 | Finalize Natural Resource Evaluation Report | 10d | 2019-09-18 | 2019-10-01 | 136 | 95d | 46d | 761 |
| 139 | 3.4.17 | Submit CRAS to OEM | 20d | 2019-12-05 | 2020-01-01 | 136, 117, 137 | 39d | 0d |  |
| 140 | 3.4.18 | SHPO Consultation Complete | 1d | 2020-01-02 | 2020-01-02 | 139 | 39d |  | 762 |
| 141 | 3.4.19 | Submit NRE to USFWS | 1d | 2019-12-05 | 2019-12-05 | 117, 138 | 49d | 0d |  |
| 142 | 3.4.20 | Submit NRE to NMFS | 1d | 2019-12-05 | 2019-12-05 | 117, 138 | 49d | 0d |  |
| 143 | 3.4.21 | Informal USFWS Consultation Complete | 10d | 2019-12-06 | 2019-12-19 | 141 | 49d |  | 752 |
| 144 | 3.4.22 | Informal NMFS Consultation Complete | 10d | 2019-12-06 | 2019-12-19 | 142 | 49d |  | 763 |
| 145 | 3.4.23 | Prepare Conceptual Relocation Plan | 20d | 2019-12-05 | 2020-01-01 | 117 | 40d |  |  |

| ID | WBS | Task | Type | Duration | Start | Finish | Predecessors | Total slack | Free slack | PSM Codes |
| --- | --- | --- | --- | --- | --- | --- | --- | --- | --- | --- |
| 146 | 3.5 | **FINAL ENVIRONMENTAL IMPACT STATEMENT DOCUMENTS** |  | 434d? | 2020-02-27 | 2021-10-26 |  | 0d |  |  |
| 147 | 3.5.1 | Prepare 1st DRAFT Environmental Impact Statement |  | 50d | 2020-02-27 | 2020-05-06 | 117, 11, 140, 143, 144, 145, 8, 54, 121 | 0d |  |  |
| 148 | 3.5.2 | District Review DRAFT Environmental Impact Statement |  | 20d | 2020-05-07 | 2020-06-03 | 147 | 0d |  | 713 |
| 149 | 3.5.3 | Prepare 2nd DRAFT Environmental Impact Statement |  | 30d | 2020-06-04 | 2020-07-15 | 148 | 0d |  |  |
| 150 | 3.5.4 | OEM Review of 2nd DRAFT Environmental Impact Statement |  | 20d | 2020-07-16 | 2020-08-12 | 149 | 0d |  |  |
| 151 | 3.5.5 | Central Office Legal Sufficiency Review |  | 20d | 2020-07-16 | 2020-08-12 | 149 | 0d |  | 735 |
| 152 | 3.5.6 | Prepare 3rd DRAFT Environmental Impact Statement |  | 20d | 2020-08-13 | 2020-09-09 | 150, 151 | 0d |  |  |
| 153 | 3.5.7 | OEM Review of 3rd DRAFT Environmental Impact Statement |  | 20d | 2020-09-10 | 2020-10-07 | 152 | 0d |  |  |
| 154 | 3.5.8 | Prepare 4th DRAFT Environmental Impact Statement |  | 30d | 2020-10-08 | 2020-11-18 | 153 | 0d |  |  |
| 155 | 3.5.9 | Cooperating Agencies Review of 4th DRAFT Environmental Impact Statement |  | 20d | 2020-11-19 | 2020-12-16 | 154 | 0d |  |  |
| 156 | 3.5.10 | Prepare 5th DRAFT Environmental Impact Statement |  | 30d | 2020-12-17 | 2021-01-27 | 155 | 0d |  |  |
| 157 | 3.5.11 | Submit 5th DRAFT Environmental Impact Statement to OEM |  | 1d | 2021-01-28 | 2021-01-28 | 156 | 0d |  | 714 |
| 158 | 3.5.12 | DRAFT Environmental Impact Statement OEM Approval |  | 1d | 2021-01-29 | 2021-01-29 | 157 | 0d |  | 715 |
| 159 | 3.5.13 | Upload DRAFT Environmental Impact Statement to ETDM for Electronic Distribution |  | 1d | 2021-02-01 | 2021-02-01 | 158 | 191d |  |  |
| 160 | 3.5.14 | Distribute DRAFT Environmental Impact Statement (Hard Copies) |  | 1d | 2021-02-01 | 2021-02-01 | 158 | 191d |  |  |
| 161 | 3.5.15 | District Files DRAFT Environmental Impact Statement with EPA |  | 1d | 2021-02-01 | 2021-02-01 | 158 | 29d | 0d |  |
| 162 | 3.5.16 | EPA Publishes Notice of Availability in Federal Register |  | 40d | 2021-02-02 | 2021-03-29 | 161 | 29d |  |  |
| 163 | 3.5.17 | Finalize Engineering & Environmental Reports |  | 10d | 2021-05-25 | 2021-06-07 | 162, 83 | 0d |  |  |
| 164 | 3.5.18 | Finalize Section 4(f) Evaluation |  | 5d | 2021-05-25 | 2021-05-31 | 162, 83 | 5d |  | 751 |
| 165 | 3.5.19 | Finalize Noise Study Report |  | 5d | 2021-05-25 | 2021-05-31 | 162, 83 | 5d |  | 335 |
| 166 | 3.5.20 | Finalize Preliminary Engineering Report |  | 5d | 2021-05-25 | 2021-05-31 | 162, 83 | 5d |  | 760 |
| 167 | 3.5.21 | Prepare FINAL Environmental Impact Statement |  | 10d | 2021-06-08 | 2021-06-21 | 83, 163, 164, 165, 166 | 0d |  |  |
| 168 | 3.5.22 | FINAL Environmental Impact Statement to OEM |  | 1d | 2021-06-22 | 2021-06-22 | 167 | 0d |  | 718 |
| 169 | 3.5.23 | OEM Review of FINAL Environmental Impact Statement |  | 5d | 2021-06-23 | 2021-06-29 | 168 | 0d |  |  |
| 170 | 3.5.24 | Cooperating Agencies Review of FINAL Environmental Impact Statement |  | 5d | 2021-06-30 | 2021-07-06 | 169 | 0d |  |  |
| 171 | 3.5.25 | Prepare DRAFT Record of Decision |  | 5d | 2021-07-07 | 2021-07-13 | 169, 170 | 0d |  |  |
| 172 | 3.5.26 | OEM Review of DRAFT Record of Decision |  | 5d | 2021-07-14 | 2021-07-20 | 171, 170 | 0d |  |  |
| 173 | 3.5.27 | CO Legal Suffiency Review (FEIS and ROD) |  | 5d | 2021-07-21 | 2021-07-27 | 168, 172 | 0d |  |  |
| 174 | 3.5.28 | OEM Approves FINAL Environmental Impact Statement and Record of Decision |  | 1d | 2021-07-28 | 2021-07-28 | 173 | 0d |  |  |
| 175 | 3.5.29 | Upload FINAL Environmental Impact Statement to ETDM for Electronic Distribution |  | 1d | 2021-07-29 | 2021-07-29 | 174 | 0d |  |  |
| 176 | 3.5.30 | Distribute FINAL Environmental Impact Statement (Hard Copies) |  | 1d | 2021-07-29 | 2021-07-29 | 174 | 0d |  |  |
| 177 | 3.5.31 | District Place Notice of Availability in Local Newspaper(s) |  | 1d | 2021-07-29 | 2021-07-29 | 174 | 0d |  |  |
| 178 | 3.5.32 | District Files FINAL Environmental Impact Statement with EPA |  | 1d? | 2021-07-29 | 2021-07-29 | 174 | 0d |  |  |
| 180 | 3.5.33 | OEM Signs Record of Decision and FINAL Environmental Impact Statement |  | 1d | 2021-10-08 | 2021-10-08 |  | 0d |  |  |
| 181 | 3.5.34 | Location Design Concept Acceptance | milestone | 1d | 2021-10-11 | 2021-10-11 | 180 | 0d |  | 263 |
| 182 | 3.5.35 | Publish Notification of Record of Decision and FINAL Environmental Impact Statement in Local Newspapers |  | 1d | 2021-10-12 | 2021-10-12 | 181 | 9d |  | 736 |
| 183 | 3.5.36 | Pass the Torch Meeting |  | 1d | 2021-10-26 | 2021-10-26 | 181FS+10d, 182 | 0d |  |  |
