# PLANNING, PD&E (SEIR) and DESIGN

Schedule from MS Project, 2016-08-01 to 2021-06-29.

## Calendars

- Standard: Mon-Fri 08:00-12:00, 13:00-17:00; Sat-Sun off.

## Schedule

| ID | WBS | Task | Type | Duration | Start | Finish | Predecessors | Total slack | Free slack | Constraint | PSM Codes |
| --- | --- | --- | --- | --- | --- | --- | --- | --- | --- | --- | --- |
| 1 | 1 | **PLANNING ACTIVITIES** |  | 251d | 2016-08-01 | 2017-07-17 |  | 0d |  |  |  |
| 2 | 1.1 | District SWAT Planning Meeting (May take place 6 months to 5 years before SWAT Kickoff Meeting) | milestone | 1d | 2016-08-01 | 2016-08-01 |  | 0d |  | start no earlier than 2016-08-01 | 746 |
| 3 | 1.2 | District SWAT Strategy Meeting (6 months after the SWAT Planning Meeting when the Tentative Work Program has been submitted) | manual | 2d | 2017-02-01 | 2017-02-02 | 2FS+131d |  |  |  |  |
| 4 | 1.3 | **ETDM PROGRAMMING SCREEN** |  | 97d | 2017-03-03 | 2017-07-17 |  | 0d |  |  |  |
| 5 | 1.3.1 | **ETDM Programming Screen Meeting** |  | 20d | 2017-03-03 | 2017-03-30 |  | 0d |  |  |  |
| 6 | 1.3.1.1 | ETDM Programming Screen PED |  | 20d | 2017-03-03 | 2017-03-30 | 3FS+20d | 0d |  |  |  |
| 7 | 1.3.1.2 | ETDM Programming Screen Purpose and Need |  | 20d | 2017-03-03 | 2017-03-30 | 3FS+20d | 0d |  |  |  |
| 8 | 1.3.1.3 | Planning Consistency Completion |  | 5d | 2017-03-03 | 2017-03-09 | 3FS+20d | 15d |  |  | 710 |
| 9 | 1.3.2 | ETDM PROGRAMMING SCREEN START/ADVANCE NOTIFICATION |  | 32d | 2017-03-31 | 2017-05-15 | 6, 7, 8 | 0d |  |  | 700, 224 |
| 10 | 1.3.3 | ETDM Programming Screen Responses |  | 44d | 2017-05-16 | 2017-07-14 | 9 | 0d |  |  |  |
| 11 | 1.3.4 | ETDM PROGRAMMING PRELIMINARY SUMMARY REPORT PUBLISHED |  | 1d | 2017-07-17 | 2017-07-17 | 10 | 0d |  |  | 701 |
| 12 | 2 | **PRE-PD&E ACTIVITIES** |  | 261d | 2017-08-01 | 2018-07-31 |  | 0d |  |  |  |
| 13 | 2.1 | SWAT Kickoff Meeting | milestone | 1d | 2017-08-01 | 2017-08-01 | 11FS+10d | 0d |  |  | 747 |
| 14 | 2.2 | Assign PD&E Project Manager |  | 1d | 2017-08-02 | 2017-08-02 | 13 | 0d |  |  | 704 |
| 15 | 2.3 | **TRAFFIC FORECAST ANALYSIS** |  | 116d | 2017-08-03 | 2018-01-11 | 7 | 0d |  |  |  |
| 16 | 2.3.1 | Traffic Methodology Meeting |  | 1d | 2017-08-03 | 2017-08-03 | 7, 14, 13 | 0d |  |  |  |
| 17 | 2.3.2 | Traffic Methodology Memorandum |  | 10d | 2017-08-04 | 2017-08-17 | 16 | 0d |  |  |  |
| 18 | 2.3.3 | Traffic Data Collection |  | 20d | 2017-08-18 | 2017-09-14 | 17 | 0d |  |  |  |
| 19 | 2.3.4 | Prepare Traffic Projections |  | 40d | 2017-09-15 | 2017-11-09 | 18 | 0d |  |  |  |
| 20 | 2.3.5 | Draft Project Traffic Forecast Report |  | 20d | 2017-11-10 | 2017-12-07 | 19 | 0d |  |  |  |
| 21 | 2.3.6 | FDOT Review - Draft Project Traffic Forecast Report |  | 15d | 2017-12-08 | 2017-12-28 | 20 | 0d |  |  |  |
| 22 | 2.3.7 | Final Project Traffic Forecast Report |  | 10d | 2017-12-29 | 2018-01-11 | 21 | 0d |  |  | 757 |
| 23 | 2.4 | **INTERCHANGE ACCESS REQUEST** |  | 247d | 2017-08-03 | 2018-07-13 |  | 94d |  |  |  |
| 24 | 2.4.1 | Initiate IJR/IMR/SIMR or IOAR |  | 1d | 2017-08-03 | 2017-08-03 | 9, 14 | 169d | 0d |  |  |
| 25 | 2.4.2 | Prepare MLOU |  | 5d | 2017-08-04 | 2017-08-10 | 24 | 169d | 0d |  |  |
| 26 | 2.4.3 | DIRC/SPO Review of MLOU |  | 10d | 2017-08-11 | 2017-08-24 | 25 | 169d | 75d |  |  |
| 27 | 2.4.4 | Develop Alternatives |  | 30d | 2017-12-08 | 2018-01-18 | 20, 26 | 94d | 0d |  |  |
| 28 | 2.4.5 | Perform Operational Analysis |  | 30d | 2018-01-19 | 2018-03-01 | 27 | 94d | 0d |  |  |
| 29 | 2.4.6 | Prepare Preliminary IMR/IJR |  | 45d | 2018-03-02 | 2018-05-03 | 28 | 94d | 0d |  |  |
| 30 | 2.4.7 | DIRC/SPO Review of Preliminary IJR/IMR |  | 10d | 2018-05-04 | 2018-05-17 | 29 | 94d | 0d |  |  |
| 31 | 2.4.8 | Prepare Final IJR/IMR |  | 30d | 2018-05-18 | 2018-06-28 | 30 | 94d | 0d |  |  |
| 32 | 2.4.9 | DIRC/SPO Review of Final IJR/IMR |  | 10d | 2018-06-29 | 2018-07-12 | 31 | 94d | 0d |  |  |
| 33 | 2.4.10 | IJR/IMR Approval |  | 1d | 2018-07-13 | 2018-07-13 | 32 | 94d |  |  | 765 |

| ID | WBS | Task | Type | Duration | Start | Finish | Predecessors | Total slack | Free slack | Constraint | PSM Codes |
| --- | --- | --- | --- | --- | --- | --- | --- | --- | --- | --- | --- |
| 34 | 2.5 | **DESIGN RELATED ACTIVITIES** |  | 80d | 2017-09-14 | 2018-01-03 |  | 6d |  |  |  |
| 35 | 2.5.1 | Design Survey and ROW Mapping |  | 80d | 2017-09-14 | 2018-01-03 | 14FS+30d | 6d |  |  |  |
| 36 | 2.5.2 | Geotechnical Investigations |  | 80d | 2017-09-14 | 2018-01-03 | 14FS+30d | 6d |  |  |  |
| 37 | 2.5.3 | Pavement Coring Evaluation Report |  | 80d | 2017-09-14 | 2018-01-03 | 14FS+30d | 6d |  |  |  |
| 38 | 2.6 | **DEVELOP SCOPE AND SCHEDULE** |  | 21d | 2018-01-12 | 2018-02-09 |  | 0d |  |  |  |
| 39 | 2.6.1 | Begin PD&E Scope and Schedule |  | 20d | 2018-01-12 | 2018-02-08 | 11, 22, 35, 36, 37 | 0d |  |  |  |
| 40 | 2.6.2 | PD&E SCOPE AND SCHEDULE COMPLETION |  | 1d | 2018-02-09 | 2018-02-09 | 39 | 0d |  |  | 703 |
| 41 | 2.7 | **PROCUREMENT** |  | 122d | 2018-02-12 | 2018-07-31 |  | 0d |  |  |  |
| 42 | 2.7.1 | PD&E Advertisement |  | 1d | 2018-02-12 | 2018-02-12 | 40 | 0d |  |  | 705 |
| 43 | 2.7.2 | Procurement |  | 120d | 2018-02-13 | 2018-07-30 | 40, 42 | 0d |  |  |  |
| 44 | 2.7.3 | Notice to Proceed | milestone | 1d | 2018-07-31 | 2018-07-31 | 43 | 0d |  | start no earlier than 2016-04-01 |  |
| 45 | 3 | **PD&E STUDY** |  | 427d | 2018-08-01 | 2020-03-19 |  | 0d |  |  |  |
| 46 | 3.1 | **PROJECT MANAGEMENT** |  | 7d | 2018-08-01 | 2018-08-09 |  | 0d |  |  |  |
| 47 | 3.1.1 | SEIR START |  | 1d | 2018-08-01 | 2018-08-01 | 44 | 0d |  |  | 709 |
| 48 | 3.1.2 | Prepare Project Management Plan |  | 5d | 2018-08-02 | 2018-08-08 | 47 | 0d |  |  |  |
| 49 | 3.1.3 | Prepare QC Plan |  | 5d | 2018-08-02 | 2018-08-08 | 47 | 0d |  |  |  |
| 50 | 3.1.4 | Project Kickoff Meeting with FDOT |  | 1d | 2018-08-09 | 2018-08-09 | 48, 49 | 0d |  |  |  |
| 51 | 3.2 | **PUBLIC INVOLVEMENT** |  | 389d | 2018-08-02 | 2020-01-28 |  | 68d |  |  |  |
| 52 | 3.2.1 | Prepare Public Involvement Plan |  | 20d | 2018-08-02 | 2018-08-29 | 47 | 93d | 31d |  |  |
| 53 | 3.2.2 | Public Involvement Data Collection |  | 45d | 2018-08-10 | 2018-10-11 | 50 | 62d | 0d |  |  |
| 54 | 3.2.3 | **Prepare for Public Kickoff Meeting** |  | 47d | 2018-10-12 | 2018-12-17 |  | 62d |  |  | 365 |
| 55 | 3.2.3.1 | Site Review |  | 1d | 2018-10-12 | 2018-10-12 | 84FS-60d, 52, 53 | 62d | 0d |  |  |
| 56 | 3.2.3.2 | Newsletter |  | 20d | 2018-10-15 | 2018-11-09 | 55 | 62d | 0d |  |  |
| 57 | 3.2.3.3 | Newspaper Ad |  | 20d | 2018-10-15 | 2018-11-09 | 55 | 62d | 0d |  |  |
| 58 | 3.2.3.4 | Elected/Appointed/Property Owner Letters |  | 20d | 2018-10-15 | 2018-11-09 | 55 | 62d | 0d |  |  |
| 59 | 3.2.3.5 | Presentation/Display Material Review |  | 15d | 2018-11-12 | 2018-11-30 | 58, 56, 57 | 62d | 0d |  |  |
| 60 | 3.2.3.6 | Public Kickoff Meeting | milestone | 1d | 2018-12-03 | 2018-12-03 | 84, 81, 82, 83, 86, 59 | 62d | 0d |  |  |
| 61 | 3.2.3.7 | Public Comment Period |  | 10d | 2018-12-04 | 2018-12-17 | 60 | 62d | 33d |  |  |

| ID | WBS | Task | Type | Duration | Start | Finish | Predecessors | Total slack | Free slack | PSM Codes |
| --- | --- | --- | --- | --- | --- | --- | --- | --- | --- | --- |
| 62 | 3.2.4 | **Prepare for Public Information Meeting** |  | 76d | 2019-02-01 | 2019-05-17 |  | 0d |  | 365 |
| 63 | 3.2.4.1 | Site Review |  | 1d | 2019-02-01 | 2019-02-01 | 103FS-60d, 61 | 29d | 0d |  |
| 64 | 3.2.4.2 | Newsletter |  | 20d | 2019-02-04 | 2019-03-01 | 63 | 29d | 0d |  |
| 65 | 3.2.4.3 | Newspaper Ad |  | 20d | 2019-02-04 | 2019-03-01 | 63 | 29d | 0d |  |
| 66 | 3.2.4.4 | Elected/Appointed/Property Owner Letters |  | 20d | 2019-02-04 | 2019-03-01 | 63 | 29d | 0d |  |
| 67 | 3.2.4.5 | Presentation/Display Material Review |  | 15d | 2019-03-04 | 2019-03-22 | 63, 64, 65, 66 | 29d |  |  |
| 68 | 3.2.4.6 | Public Information Meeting | milestone | 1d | 2019-05-03 | 2019-05-03 | 103FS+5d, 67 | 0d |  | 292 |
| 69 | 3.2.4.7 | Public Comment Period |  | 10d | 2019-05-06 | 2019-05-17 | 68 | 0d |  |  |
| 70 | 3.2.5 | **Prepare for Public Hearing** |  | 101d | 2019-09-10 | 2020-01-28 |  | 333d |  | 366 |
| 71 | 3.2.5.1 | Site Review |  | 20d | 2019-09-10 | 2019-10-07 | 69, 141FS-80d | 353d | 0d |  |
| 72 | 3.2.5.2 | Newsletter |  | 20d | 2019-10-08 | 2019-11-04 | 71 | 353d | 0d |  |
| 73 | 3.2.5.3 | Newspaper Ad |  | 20d | 2019-10-08 | 2019-11-04 | 71 | 353d | 0d |  |
| 74 | 3.2.5.4 | Elected/Appointed/Property Owner Letters |  | 20d | 2019-10-08 | 2019-11-04 | 71 | 353d | 0d |  |
| 75 | 3.2.5.5 | Presentation/Display Material Review |  | 15d | 2019-11-05 | 2019-11-25 | 71, 72, 73, 74 | 353d | 20d |  |
| 76 | 3.2.5.6 | Notice of Public Availability |  | 15d | 2019-12-24 | 2020-01-13 | 75, 141FS-5d, 113, 114, 33 | 333d | 0d |  |
| 77 | 3.2.5.7 | Public Hearing | milestone | 1d | 2020-01-14 | 2020-01-14 | 76, 75 | 333d | 0d | 262 |
| 78 | 3.2.5.8 | Public Comment Period |  | 10d | 2020-01-15 | 2020-01-28 | 77 | 333d | 0d |  |
| 79 | 3.3 | **ENGINEERING ANALYSIS** |  | 341d | 2018-08-10 | 2019-11-29 |  | 0d |  |  |
| 80 | 3.3.1 | **Data Collection** |  | 30d | 2018-08-10 | 2018-09-20 |  | 113d |  |  |
| 81 | 3.3.1.1 | Roadway Data Collection |  | 30d | 2018-08-10 | 2018-09-20 | 50 | 113d | 51d |  |
| 82 | 3.3.1.2 | Drainage Data Collection |  | 30d | 2018-08-10 | 2018-09-20 | 50 | 113d | 51d |  |
| 83 | 3.3.1.3 | Bridge Data Collection |  | 30d | 2018-08-10 | 2018-09-20 | 50 | 113d | 51d |  |
| 84 | 3.3.1.4 | Prepare Base Map |  | 30d | 2018-08-10 | 2018-09-20 | 50 | 113d | 51d |  |
| 85 | 3.3.2 | **Traffic Analysis** |  | 95d | 2018-08-10 | 2018-12-20 |  | 0d |  |  |
| 86 | 3.3.2.1 | Crash Data and Analysis |  | 20d | 2018-08-10 | 2018-09-06 | 50 | 123d | 61d |  |
| 87 | 3.3.2.2 | Prepare Capacity Analysis |  | 30d | 2018-08-10 | 2018-09-20 | 50 | 0d |  |  |
| 88 | 3.3.2.3 | Draft Project Traffic Analysis Report |  | 20d | 2018-09-21 | 2018-10-18 | 87 | 0d |  |  |
| 89 | 3.3.2.4 | FDOT Review - Draft Project Traffic Analysis Report |  | 15d | 2018-10-19 | 2018-11-08 | 88 | 0d |  |  |
| 90 | 3.3.2.5 | Final Project Traffic Analysis Report |  | 10d | 2018-11-09 | 2018-11-22 | 89 | 0d |  | 757 |
| 91 | 3.3.2.6 | Prepare 18Kip ESALs Traffic Data |  | 20d | 2018-11-23 | 2018-12-20 | 90 | 206d |  |  |

| ID | WBS | Task | Duration | Start | Finish | Predecessors | Total slack | Free slack | PSM Codes |
| --- | --- | --- | --- | --- | --- | --- | --- | --- | --- |
| 92 | 3.3.3 | **Alternative Analysis** | 291d | 2018-10-19 | 2019-11-29 |  | 25d |  |  |
| 93 | 3.3.3.1 | Typical Sections Analysis | 30d | 2018-10-19 | 2018-11-29 | 88 | 65d |  |  |
| 94 | 3.3.3.2 | Complete Streets/Multi Modal Analysis | 30d | 2018-10-19 | 2018-11-29 | 88 | 65d |  |  |
| 95 | 3.3.3.3 | Concept Development | 40d | 2018-11-23 | 2019-01-17 | 87, 90, 33 | 0d |  |  |
| 96 | 3.3.3.4 | Access Management Analysis | 40d | 2018-11-23 | 2019-01-17 | 90 | 30d |  |  |
| 97 | 3.3.3.5 | Drainage Analysis | 30d | 2019-01-18 | 2019-02-28 | 95 | 0d |  |  |
| 98 | 3.3.3.6 | Utility Coordination & Analysis | 30d | 2019-01-18 | 2019-02-28 | 95 | 0d |  |  |
| 99 | 3.3.3.7 | Railroad Coordination | 30d | 2019-01-18 | 2019-02-28 | 95 | 0d |  |  |
| 100 | 3.3.3.8 | Evaluation Matrix (1st Draft) | 5d | 2019-03-01 | 2019-03-07 | 93, 94, 97, 98, 99, 96, 95 | 0d |  |  |
| 101 | 3.3.3.9 | Construction Cost Estimates (LRE) | 10d | 2019-03-08 | 2019-03-21 | 100 | 20d |  |  |
| 102 | 3.3.3.10 | Right-of-Way Analysis | 20d | 2019-03-08 | 2019-04-04 | 100 | 10d |  |  |
| 103 | 3.3.3.11 | Evaluation Matrix (2nd Draft) | 5d | 2019-04-19 | 2019-04-25 | 101, 102, 116, 117, 118, 119, 120, 121 | 0d |  |  |
| 104 | 3.3.3.12 | Refine Alternatives (based on public input) | 20d | 2019-05-20 | 2019-06-14 | 69 | 532d |  |  |
| 105 | 3.3.3.13 | Prepare 1st DRAFT Engineering Reports (Drainage, Utility, Roadway Plans, ITS, Lighting, Pavement, Geotech, PER) | 30d | 2019-05-20 | 2019-06-28 | 69, 22, 90 | 0d |  |  |
| 106 | 3.3.3.14 | FDOT Review - 1st DRAFT Engineering Reports | 20d | 2019-07-01 | 2019-07-26 | 105 | 0d |  |  |
| 107 | 3.3.3.15 | Update DRAFT Engineering Reports | 15d | 2019-07-29 | 2019-08-16 | 106 | 0d |  |  |
| 108 | 3.3.3.16 | VE Study | 5d | 2019-08-19 | 2019-08-23 | 107 | 0d |  |  |
| 109 | 3.3.3.17 | VE Issues Resolution | 10d | 2019-09-23 | 2019-10-04 | 108FS+20d | 0d |  |  |
| 110 | 3.3.3.18 | Prepare Typical Section Package | 20d | 2019-10-07 | 2019-11-01 | 109 | 0d |  |  |
| 111 | 3.3.3.19 | Prepare Design Variations and Exceptions | 20d | 2019-10-07 | 2019-11-01 | 109 | 0d |  |  |
| 112 | 3.3.3.20 | Prepare Pavement Design Report | 20d | 2019-10-07 | 2019-11-01 | 109, 91 | 0d |  |  |
| 113 | 3.3.3.21 | Typical Section Selection | 20d | 2019-11-04 | 2019-11-29 | 110, 111, 112 | 0d |  | 759 |
| 114 | 3.3.3.22 | FDOT Review - 2nd DRAFT Engineering Reports (Drainage, Utility, Roadway Plans, ITS, Lighting, Pavement, Geotech, PER) | 20d | 2019-11-04 | 2019-11-29 | 110 | 349d | 16d |  |
| 115 | 3.4 | **ENVIRONMENTAL ANALYSIS** | 172d | 2019-03-08 | 2019-11-04 |  | 0d |  |  |
| 116 | 3.4.1 | Data Collection & Cultural Resources Assessment Survey | 30d | 2019-03-08 | 2019-04-18 | 100 | 0d |  |  |
| 117 | 3.4.2 | Data Collection & Noise Analysis | 30d | 2019-03-08 | 2019-04-18 | 100 | 0d |  |  |
| 118 | 3.4.3 | Data Collection & Contamination Screen Evaluation | 30d | 2019-03-08 | 2019-04-18 | 100 | 0d |  |  |
| 119 | 3.4.4 | Wetland Delineation and Evaluation | 30d | 2019-03-08 | 2019-04-18 | 100 | 0d |  |  |
| 120 | 3.4.5 | Data Collection & Wildlife Survey | 30d | 2019-03-08 | 2019-04-18 | 100 | 0d |  |  |
| 121 | 3.4.6 | Essential Fish Habitat Evaluation | 30d | 2019-03-08 | 2019-04-18 | 100 | 0d |  |  |
| 122 | 3.4.7 | Determination of Section 4(f) | 15d | 2019-03-08 | 2019-03-28 | 100 | 394d | 0d |  |
| 123 | 3.4.8 | Prepare 1st Draft Natural Resource Evaluation Report | 30d | 2019-04-19 | 2019-05-30 | 119, 120, 121 | 379d | 0d |  |
| 124 | 3.4.9 | Prepare 1st Draft Cultural Resources Assessment Survey | 30d | 2019-04-19 | 2019-05-30 | 116 | 379d | 0d |  |
| 125 | 3.4.10 | Prepare 1st Draft Contamination Screen Evaluation Report | 30d | 2019-04-19 | 2019-05-30 | 118 | 379d | 0d |  |
| 126 | 3.4.11 | Prepare 1st Draft Noise Study Report | 30d | 2019-04-19 | 2019-05-30 | 117 | 379d | 0d |  |
| 127 | 3.4.12 | Prepare Draft Section 4(f) Evaluation | 30d | 2019-03-29 | 2019-05-09 | 122 | 394d | 15d |  |
| 128 | 3.4.13 | FDOT Review 1st DRAFT Environmental Reports (NRE, CSER, CRAS, Noise, Section 4(f)) | 20d | 2019-05-31 | 2019-06-27 | 123, 124, 125, 126, 127 | 379d | 0d |  |
| 129 | 3.4.14 | Update Environmental Reports | 15d | 2019-06-28 | 2019-07-18 | 128 | 379d | 0d |  |
| 130 | 3.4.15 | Finalize Cultural Resources Assessment Survey | 10d | 2019-07-19 | 2019-08-01 | 129 | 379d | 46d | 333 |
| 131 | 3.4.16 | Finalize Natural Resource Evaluation Report | 10d | 2019-07-19 | 2019-08-01 | 129 | 389d | 46d | 761 |
| 132 | 3.4.17 | Submit CRAS to OEM | 20d | 2019-10-07 | 2019-11-01 | 129, 109, 130 | 333d | 0d |  |
| 133 | 3.4.18 | SHPO Consultation Complete | 1d | 2019-11-04 | 2019-11-04 | 132 | 333d | 0d | 762 |
| 134 | 3.4.19 | Submit NRE to USFWS | 1d | 2019-10-07 | 2019-10-07 | 109, 131 | 343d | 0d |  |
| 135 | 3.4.20 | Submit NRE to NMFS | 1d | 2019-10-07 | 2019-10-07 | 109, 131 | 343d | 0d |  |
| 136 | 3.4.21 | Informal USFWS Consultation Complete | 10d | 2019-10-08 | 2019-10-21 | 134 | 343d | 10d | 752 |
| 137 | 3.4.22 | Informal NMFS Consultation Complete | 10d | 2019-10-08 | 2019-10-21 | 135 | 343d | 10d | 763 |
| 138 | 3.4.23 | Prepare Conceptual Relocation Plan | 20d | 2019-10-07 | 2019-11-01 | 109 | 334d | 1d |  |

| ID | WBS | Task | Type | Duration | Start | Finish | Predecessors | Total slack | Free slack | PSM Codes |
| --- | --- | --- | --- | --- | --- | --- | --- | --- | --- | --- |
| 139 | 3.5 | **FINAL SEIR DOCUMENTS** |  | 98d | 2019-11-05 | 2020-03-19 |  | 333d |  |  |
| 140 | 3.5.1 | Prepare DRAFT SEIR |  | 20d | 2019-11-05 | 2019-12-02 | 109, 11, 133, 136, 137, 138 | 333d | 0d |  |
| 141 | 3.5.2 | FDOT Review DRAFT SEIR |  | 20d | 2019-12-03 | 2019-12-30 | 140 | 333d | 0d | 713 |
| 142 | 3.5.3 | Finalize Engineering & Environmental Reports |  | 10d | 2020-01-29 | 2020-02-11 | 78 | 338d | 5d | 756 |
| 143 | 3.5.4 | Finalize Section 4(f) Evaluation |  | 5d | 2020-01-29 | 2020-02-04 | 78 | 333d | 0d | 751 |
| 144 | 3.5.5 | Finalize Noise Study Report |  | 5d | 2020-01-29 | 2020-02-04 | 78 | 333d | 0d | 335 |
| 145 | 3.5.6 | Finalize Preliminary Engineering Report |  | 5d | 2020-01-29 | 2020-02-04 | 78 | 343d | 10d | 760 |
| 146 | 3.5.7 | Prepare FINAL SEIR |  | 10d | 2020-02-05 | 2020-02-18 | 78, 143, 144 | 333d | 0d |  |
| 147 | 3.5.8 | Submit FINAL SEIR to District OEM |  | 20d | 2020-02-19 | 2020-03-17 | 146, 142, 145 | 333d | 0d |  |
| 148 | 3.5.9 | District Secretary Approval of SEIR | milestone | 0d | 2020-03-19 | 2020-03-19 | 147FS+2d | 333d |  | 722 |
| 149 | 4 | **FINAL DESIGN** |  | 412d | 2019-12-02 | 2021-06-29 |  | 0d |  |  |
| 150 | 4.1 | **60% (PHASE II) PLANS** |  | 116d | 2019-12-02 | 2020-05-11 |  | 0d |  |  |
| 151 | 4.1.1 | Prepare 60% (Phase II) Plans |  | 80d | 2019-12-02 | 2020-03-20 | 113 | 0d |  |  |
| 152 | 4.1.2 | Submit 60% Plans & Quantities to FDOT | milestone | 0d | 2020-03-20 | 2020-03-20 | 151 | 0d |  | 302 |
| 153 | 4.1.3 | FDOT Review of Phase II Plans |  | 20d | 2020-03-23 | 2020-04-17 | 152 | 44d | 0d |  |
| 154 | 4.1.4 | Utility Review & Conflict Resolution |  | 15d | 2020-04-20 | 2020-05-08 | 153 | 44d | 0d |  |
| 155 | 4.1.5 | Prepare and Submit Permit Applications |  | 15d | 2020-04-20 | 2020-05-08 | 153 | 45d | 1d |  |
| 156 | 4.1.6 | ROW Coordination Meeting 60% |  | 1d | 2020-05-11 | 2020-05-11 | 154 | 44d | 0d |  |
| 157 | 4.2 | **90% (PHASE III) PLANS** |  | 86d | 2020-05-12 | 2020-09-08 |  | 44d |  |  |
| 158 | 4.2.1 | Prepare 90% (Phase III) Plans & Quantities |  | 50d | 2020-05-12 | 2020-07-20 | 155, 156 | 44d | 0d |  |
| 159 | 4.2.2 | Submit 90% Plans & Quantities to FDOT | milestone | 0d | 2020-07-20 | 2020-07-20 | 158 | 44d | 0d | 303 |
| 160 | 4.2.3 | FDOT Review of 90% Plans |  | 20d | 2020-07-21 | 2020-08-17 | 159 | 44d | 0d |  |
| 161 | 4.2.4 | Utility Review & Conflict Resolution |  | 15d | 2020-08-18 | 2020-09-07 | 160 | 44d | 0d |  |
| 162 | 4.2.5 | ROW Coordination Meeting 90% |  | 1d | 2020-09-08 | 2020-09-08 | 161 | 44d | 0d |  |

| ID | WBS | Task | Type | Duration | Start | Finish | Predecessors | Total slack | Free slack | PSM Codes |
| --- | --- | --- | --- | --- | --- | --- | --- | --- | --- | --- |
| 163 | 4.3 | **100% (PHASE IV) PLANS** |  | 50d | 2020-09-09 | 2020-11-17 |  | 44d |  |  |
| 164 | 4.3.1 | Prepare 100% (Phase IV) Submittal |  | 30d | 2020-09-09 | 2020-10-20 | 162 | 44d | 0d |  |
| 165 | 4.3.2 | Submit 100% (Phase IV) Submittal to FDOT | milestone | 0d | 2020-10-20 | 2020-10-20 | 164 | 44d | 0d | 306 |
| 166 | 4.3.3 | FDOT Review of 100% (Phase IV) Submittal |  | 20d | 2020-10-21 | 2020-11-17 | 165 | 44d | 0d |  |
| 167 | 4.4 | **RIGHT OF WAY ACQUISITION** |  | 376d | 2019-12-02 | 2021-05-10 |  | 0d |  |  |
| 168 | 4.4.1 | Determine and Submit ROW Requirements to R/W Office |  | 60d | 2019-12-02 | 2020-02-21 | 113 | 20d |  | 322 |
| 169 | 4.4.2 | Final ROW Map/Sketches and Legals to R/W Administration |  | 20d | 2020-03-23 | 2020-04-17 | 152, 168 | 0d |  | 139 |
| 170 | 4.4.3 | Submit Documents to R/W Administration | milestone | 0d | 2020-04-17 | 2020-04-17 | 169 | 0d |  | 268 |
| 171 | 4.4.4 | Appraisals Review |  | 1d | 2020-04-20 | 2020-04-20 | 170 | 0d |  | 143 |
| 172 | 4.4.5 | Perform R/W Appraisals |  | 120d | 2020-04-21 | 2020-10-05 | 171 | 0d |  | 120 |
| 173 | 4.4.6 | Negotiations and Land Acquisition |  | 120d | 2020-07-14 | 2020-12-28 | 172SS+60d | 0d |  | 121 |
| 174 | 4.4.7 | Final ROW Order of Taking | milestone | 0d | 2020-12-28 | 2020-12-28 | 173 | 0d |  | 273 |
| 175 | 4.4.8 | Condemnation |  | 60d | 2020-12-29 | 2021-03-22 | 174 | 0d |  | 122 |
| 176 | 4.4.9 | ROW Demo & Clear |  | 60d | 2021-02-09 | 2021-05-03 | 175SS+30d | 0d |  | 125 |
| 177 | 4.4.10 | ROW Certified | milestone | 0d | 2021-05-10 | 2021-05-10 | 176FS+5d | 0d |  | 255 |
| 178 | 4.5 | **FINAL PLANS** |  | 129d | 2020-11-18 | 2021-05-17 |  | 0d |  |  |
| 179 | 4.5.1 | Plans Completed |  | 60d | 2020-11-18 | 2021-02-09 | 166 | 44d | 0d | 201 |
| 180 | 4.5.2 | Review Final Plans by Estimate & Construction Office |  | 20d | 2021-02-10 | 2021-03-09 | 179 | 44d | 0d |  |
| 181 | 4.5.3 | ADA Certification | milestone | 0d | 2021-03-16 | 2021-03-16 | 180FS+5d | 44d |  |  |
| 182 | 4.5.4 | All Permits Clear | milestone | 0d | 2021-03-16 | 2021-03-16 | 180FS+5d | 44d |  | 222 |
| 183 | 4.5.5 | Utilities Clear | milestone | 0d | 2021-03-16 | 2021-03-16 | 180FS+5d | 44d |  | 269 |
| 184 | 4.5.6 | Railroad Clear | milestone | 0d | 2021-03-16 | 2021-03-16 | 180FS+5d | 44d |  | 279 |
| 185 | 4.5.7 | Construction Clear | milestone | 0d | 2021-03-16 | 2021-03-16 | 180FS+5d | 44d |  | 375 |
| 186 | 4.5.8 | Environmental Clear | milestone | 0d | 2021-03-16 | 2021-03-16 | 180FS+5d | 44d |  | 376 |
| 187 | 4.5.9 | Production Date | milestone | 0d | 2021-05-17 | 2021-05-17 | 181, 182, 183, 184, 185, 186, 177FS+5d | 0d |  | 204 |

| ID | WBS | Task | Type | Duration | Start | Finish | Predecessors | Total slack | PSM Codes |
| --- | --- | --- | --- | --- | --- | --- | --- | --- | --- |
| 188 | 4.6 | **SPECIFICATIONS PACKAGE** |  | 21d | 2021-05-17 | 2021-06-15 |  | 0d |  |
| 189 | 4.6.1 | Plans to Specs | milestone | 0d | 2021-05-17 | 2021-05-17 | 187 | 0d | 226 |
| 190 | 4.6.2 | Prepare Specifications Package |  | 21d | 2021-05-18 | 2021-06-15 | 187, 189 | 0d | 242 |
| 191 | 4.7 | PLANS TO TALLAHASSEE | milestone | 0d | 2021-06-29 | 2021-06-29 | 190FS+10d | 0d | 212 |
