# Planning and PD&E (SEIR)

Schedule from MS Project, 2016-08-01 to 2020-04-03.

## Calendars

- Standard: Mon-Fri 08:00-12:00, 13:00-17:00; Sat-Sun off.

## Schedule

| ID | WBS | Task | Type | Duration | Start | Finish | Predecessors | Total slack | Free slack | Constraint | PSM Codes |
| --- | --- | --- | --- | --- | --- | --- | --- | --- | --- | --- | --- |
| 1 | 1 | **PLANNING ACTIVITIES** |  | 251d | 2016-08-01 | 2017-07-17 |  | 0d |  |  |  |
| 2 | 1.1 | District SWAT Strategy Meeting (May take place 6 months to 5 years before SWAT Kickoff Meeting) | milestone | 1d | 2016-08-01 | 2016-08-01 |  | 0d |  | start no earlier than 2016-08-01 | 746 |
| 3 | 1.2 | District SWAT Strategy Meeting (6 months after the SWAT Planning Meeting when the Tentative Work Program has been submitted) | manual | 2d | 2017-02-01 | 2017-02-02 | 2FS+131d |  |  |  |  |
| 4 | 1.3 | **ETDM PROGRAMMING SCREEN** |  | 97d | 2017-03-03 | 2017-07-17 |  | 0d |  |  |  |
| 5 | 1.3.1 | **ETDM Programming Screen Meeting** |  | 20d | 2017-03-03 | 2017-03-30 |  | 0d |  |  |  |
| 6 | 1.3.1.1 | ETDM Programming Screen PED |  | 20d | 2017-03-03 | 2017-03-30 | 3FS+20d | 0d |  |  |  |
| 7 | 1.3.1.2 | ETDM Programming Screen Purpose and Need |  | 20d | 2017-03-03 | 2017-03-30 | 3FS+20d | 0d |  |  |  |
| 8 | 1.3.1.3 | Planning Consistency Completion |  | 5d | 2017-03-03 | 2017-03-09 | 3FS+20d | 801d |  |  | 710 |
| 9 | 1.3.2 | ETDM PROGRAMMING SCREEN START/ADVANCE NOTIFICATION |  | 32d | 2017-03-31 | 2017-05-15 | 6, 7, 8 | 0d |  |  | 700, 224 |
| 10 | 1.3.3 | ETDM Programming Screen Responses |  | 44d | 2017-05-16 | 2017-07-14 | 9 | 0d |  |  |  |
| 11 | 1.3.4 | ETDM PROGRAMMING PRELIMINARY SUMMARY REPORT PUBLISHED |  | 1d | 2017-07-17 | 2017-07-17 | 10 | 0d |  |  | 701 |
| 12 | 2 | **PRE-PD&E ACTIVITIES** |  | 261d | 2017-08-01 | 2018-07-31 |  | 0d |  |  |  |
| 13 | 2.1 | SWAT Kickoff Meeting | milestone | 1d | 2017-08-01 | 2017-08-01 | 11FS+10d | 0d |  |  | 747 |
| 14 | 2.2 | Assign PD&E Project Manager |  | 1d | 2017-08-02 | 2017-08-02 | 13 | 0d |  |  | 704 |
| 15 | 2.3 | **TRAFFIC FORECAST ANALYSIS** |  | 116d | 2017-08-03 | 2018-01-11 | 7 | 0d |  |  |  |
| 16 | 2.3.1 | Traffic Methodology Meeting |  | 1d | 2017-08-03 | 2017-08-03 | 7, 14, 13 | 0d |  |  |  |
| 17 | 2.3.2 | Traffic Methodology Memorandum |  | 10d | 2017-08-04 | 2017-08-17 | 16 | 0d |  |  |  |
| 18 | 2.3.3 | Traffic Data Collection |  | 20d | 2017-08-18 | 2017-09-14 | 17 | 0d |  |  |  |
| 19 | 2.3.4 | Prepare Traffic Projections |  | 40d | 2017-09-15 | 2017-11-09 | 18 | 0d |  |  |  |
| 20 | 2.3.5 | Draft Project Traffic Analysis Report |  | 20d | 2017-11-10 | 2017-12-07 | 19 | 0d |  |  |  |
| 21 | 2.3.6 | FDOT Review - Draft Project Traffic Forecast Report |  | 15d | 2017-12-08 | 2017-12-28 | 20 | 0d |  |  |  |
| 22 | 2.3.7 | Final Project Traffic Forecast Report |  | 10d | 2017-12-29 | 2018-01-11 | 21 | 0d |  |  | 757 |
| 23 | 2.4 | **INTERCHANGE ACCESS REQUEST** |  | 247d | 2017-08-03 | 2018-07-13 |  | 94d |  |  |  |
| 24 | 2.4.1 | Initiate IJR/IMR/SIMR or IOAR |  | 1d | 2017-08-03 | 2017-08-03 | 9, 14 | 169d | 0d |  |  |
| 25 | 2.4.2 | Prepare MLOU |  | 5d | 2017-08-04 | 2017-08-10 | 24 | 169d | 0d |  |  |
| 26 | 2.4.3 | DIRC/SPO Review of MLOU |  | 10d | 2017-08-11 | 2017-08-24 | 25 | 169d | 75d |  |  |
| 27 | 2.4.4 | Develop Alternatives |  | 30d | 2017-12-08 | 2018-01-18 | 20, 26 | 94d | 0d |  |  |
| 28 | 2.4.5 | Perform Operational Analysis |  | 30d | 2018-01-19 | 2018-03-01 | 27 | 94d | 0d |  |  |
| 29 | 2.4.6 | Prepare Preliminary IMR/IJR |  | 45d | 2018-03-02 | 2018-05-03 | 28 | 94d | 0d |  |  |
| 30 | 2.4.7 | DIRC/SPO Reviw of Preliminary IJR/IMR |  | 10d | 2018-05-04 | 2018-05-17 | 29 | 94d | 0d |  |  |
| 31 | 2.4.8 | Prepare Final IJR/IMR |  | 30d | 2018-05-18 | 2018-06-28 | 30 | 94d | 0d |  |  |
| 32 | 2.4.9 | DIRC/SPO Review of Final IJR/IMR |  | 10d | 2018-06-29 | 2018-07-12 | 31 | 94d | 0d |  |  |
| 33 | 2.4.10 | IJR/IMR Approval |  | 1d | 2018-07-13 | 2018-07-13 | 32 | 94d |  |  | 765 |

| ID | WBS | Task | Type | Duration | Start | Finish | Predecessors | Total slack | Free slack | Constraint | PSM Codes |
| --- | --- | --- | --- | --- | --- | --- | --- | --- | --- | --- | --- |
| 34 | 2.5 | **DEVELOP SCOPE AND SCHEDULE** |  | 21d | 2018-01-12 | 2018-02-09 |  | 0d |  |  |  |
| 35 | 2.5.1 | Begin PD&E Scope and Schedule |  | 20d | 2018-01-12 | 2018-02-08 | 11, 22 | 0d |  |  |  |
| 36 | 2.5.2 | PD&E SCOPE AND SCHEDULE COMPLETION |  | 1d | 2018-02-09 | 2018-02-09 | 35 | 0d |  |  | 703 |
| 37 | 2.6 | **PROCUREMENT** |  | 122d | 2018-02-12 | 2018-07-31 |  | 0d |  |  |  |
| 38 | 2.6.1 | PD&E Advertisement |  | 1d | 2018-02-12 | 2018-02-12 | 36 | 0d |  |  | 705 |
| 39 | 2.6.2 | Procurement |  | 120d | 2018-02-13 | 2018-07-30 | 36, 38 | 0d |  |  |  |
| 40 | 2.6.3 | Notice to Proceed | milestone | 1d | 2018-07-31 | 2018-07-31 | 39 | 0d |  | start no earlier than 2016-04-01 |  |
| 41 | 3 | **PD&E STUDY** |  | 438d | 2018-08-01 | 2020-04-03 |  | 0d |  |  |  |
| 42 | 3.1 | **PROJECT MANAGEMENT** |  | 7d | 2018-08-01 | 2018-08-09 |  | 0d |  |  |  |
| 43 | 3.1.1 | SEIR START |  | 1d | 2018-08-01 | 2018-08-01 | 40 | 0d |  |  | 709 |
| 44 | 3.1.2 | Prepare Project Management Plan |  | 5d | 2018-08-02 | 2018-08-08 | 43 | 0d |  |  |  |
| 45 | 3.1.3 | Prepare QC Plan |  | 5d | 2018-08-02 | 2018-08-08 | 43 | 0d |  |  |  |
| 46 | 3.1.4 | Project Kickoff Meeting with FDOT |  | 1d | 2018-08-09 | 2018-08-09 | 44, 45 | 0d |  |  |  |
| 47 | 3.2 | **PUBLIC INVOLVEMENT** |  | 389d | 2018-08-02 | 2020-01-28 |  | 0d |  |  |  |
| 48 | 3.2.1 | Prepare Public Involvement Plan |  | 20d | 2018-08-02 | 2018-08-29 | 43 | 93d | 31d |  |  |
| 49 | 3.2.2 | Public Involvement Data Collection |  | 45d | 2018-08-10 | 2018-10-11 | 46 | 62d | 0d |  |  |
| 50 | 3.2.3 | **Prepare for Public Kickoff Meeting** |  | 47d | 2018-10-12 | 2018-12-17 |  | 62d |  |  | 365 |
| 51 | 3.2.3.1 | Site Review |  | 1d | 2018-10-12 | 2018-10-12 | 82FS-60d, 48, 49 | 62d | 0d |  |  |
| 52 | 3.2.3.2 | Newsletter |  | 20d | 2018-10-15 | 2018-11-09 | 51 | 62d | 0d |  |  |
| 53 | 3.2.3.3 | Newspaper Ad |  | 20d | 2018-10-15 | 2018-11-09 | 51 | 62d | 0d |  |  |
| 54 | 3.2.3.4 | Elected/Appointed/Property Owner Letters |  | 20d | 2018-10-15 | 2018-11-09 | 51 | 62d | 0d |  |  |
| 55 | 3.2.3.5 | Presentation/Display Material Review |  | 15d | 2018-11-12 | 2018-11-30 | 54, 52, 53 | 62d | 0d |  |  |
| 56 | 3.2.3.6 | Public Kickoff Meeting | milestone | 1d | 2018-12-03 | 2018-12-03 | 82, 77, 78, 79, 80, 84, 55 | 62d | 0d |  |  |
| 57 | 3.2.3.7 | Public Comment Period |  | 10d | 2018-12-04 | 2018-12-17 | 56 | 62d | 33d |  |  |

| ID | WBS | Task | Type | Duration | Start | Finish | Predecessors | Total slack | Free slack | PSM Codes |
| --- | --- | --- | --- | --- | --- | --- | --- | --- | --- | --- |
| 58 | 3.2.4 | **Prepare for Public Information Meeting** |  | 76d | 2019-02-01 | 2019-05-17 |  | 0d |  | 365 |
| 59 | 3.2.4.1 | Site Review |  | 1d | 2019-02-01 | 2019-02-01 | 100FS-60d, 57 | 29d | 0d |  |
| 60 | 3.2.4.2 | Newsletter |  | 20d | 2019-02-04 | 2019-03-01 | 59 | 29d | 0d |  |
| 61 | 3.2.4.3 | Newspaper Ad |  | 20d | 2019-02-04 | 2019-03-01 | 59 | 29d | 0d |  |
| 62 | 3.2.4.4 | Elected/Appointed/Property Owner Letters |  | 20d | 2019-02-04 | 2019-03-01 | 59 | 29d | 0d |  |
| 63 | 3.2.4.5 | Presentation/Display Material Review |  | 15d | 2019-03-04 | 2019-03-22 | 59, 60, 61, 62 | 29d |  |  |
| 64 | 3.2.4.6 | Public Information Meeting | milestone | 1d | 2019-05-03 | 2019-05-03 | 100FS+5d, 63 | 0d |  | 292 |
| 65 | 3.2.4.7 | Public Comment Period |  | 10d | 2019-05-06 | 2019-05-17 | 64 | 0d |  |  |
| 66 | 3.2.5 | **Prepare for Public Hearing** |  | 101d | 2019-09-10 | 2020-01-28 |  | 0d |  | 366 |
| 67 | 3.2.5.1 | Site Review |  | 20d | 2019-09-10 | 2019-10-07 | 65, 137FS-80d | 20d | 0d |  |
| 68 | 3.2.5.2 | Newsletter |  | 20d | 2019-10-08 | 2019-11-04 | 67 | 20d | 0d |  |
| 69 | 3.2.5.3 | Newspaper Ad |  | 20d | 2019-10-08 | 2019-11-04 | 67 | 20d | 0d |  |
| 70 | 3.2.5.4 | Elected/Appointed/Property Owner Letters |  | 20d | 2019-10-08 | 2019-11-04 | 67 | 20d | 0d |  |
| 71 | 3.2.5.5 | Presentation/Display Material Review |  | 15d | 2019-11-05 | 2019-11-25 | 67, 68, 69, 70 | 20d |  |  |
| 72 | 3.2.5.6 | Notice of Public Availability |  | 15d | 2019-12-24 | 2020-01-13 | 71, 137FS-5d, 109, 110, 33 | 0d |  |  |
| 73 | 3.2.5.7 | Public Hearing | milestone | 1d | 2020-01-14 | 2020-01-14 | 72, 71 | 0d |  | 262 |
| 74 | 3.2.5.8 | Public Comment Period |  | 10d | 2020-01-15 | 2020-01-28 | 73 | 0d |  |  |
| 75 | 3.3 | **ENGINEERING ANALYSIS** |  | 341d | 2018-08-10 | 2019-11-29 |  | 0d |  |  |
| 76 | 3.3.1 | **Data Collection** |  | 30d | 2018-08-10 | 2018-09-20 |  | 113d |  |  |
| 77 | 3.3.1.1 | Roadway Data Collection |  | 30d | 2018-08-10 | 2018-09-20 | 46 | 113d | 51d |  |
| 78 | 3.3.1.2 | Drainage Data Collection |  | 30d | 2018-08-10 | 2018-09-20 | 46 | 113d | 51d |  |
| 79 | 3.3.1.3 | Bridge Data Collection |  | 30d | 2018-08-10 | 2018-09-20 | 46 | 113d | 51d |  |
| 80 | 3.3.1.4 | Geotechnical Data Collection |  | 30d | 2018-08-10 | 2018-09-20 | 46 | 113d | 51d |  |
| 81 | 3.3.1.5 | Topographic Survey and ROW Mapping |  | 30d | 2018-08-10 | 2018-09-20 | 46 | 401d |  |  |
| 82 | 3.3.1.6 | Prepare Base Map |  | 30d | 2018-08-10 | 2018-09-20 | 46 | 113d | 51d |  |

| ID | WBS | Task | Duration | Start | Finish | Predecessors | Total slack | Free slack | PSM Codes |
| --- | --- | --- | --- | --- | --- | --- | --- | --- | --- |
| 83 | 3.3.2 | **Traffic Analysis** | 75d | 2018-08-10 | 2018-11-22 |  | 0d |  |  |
| 84 | 3.3.2.1 | Crash Data and Analysis | 20d | 2018-08-10 | 2018-09-06 | 46 | 123d | 61d |  |
| 85 | 3.3.2.2 | Prepare Capacity Analysis | 30d | 2018-08-10 | 2018-09-20 | 46 | 0d |  |  |
| 86 | 3.3.2.3 | Draft Project Traffic Analysis Report | 20d | 2018-09-21 | 2018-10-18 | 85 | 0d |  |  |
| 87 | 3.3.2.4 | FDOT Review - Draft Project Traffic Analysis Report | 15d | 2018-10-19 | 2018-11-08 | 86 | 0d |  |  |
| 88 | 3.3.2.5 | Final Project Traffic Analysis Report | 10d | 2018-11-09 | 2018-11-22 | 87 | 0d |  | 757 |
| 89 | 3.3.3 | **Alternative Analysis** | 291d | 2018-10-19 | 2019-11-29 |  | 25d |  |  |
| 90 | 3.3.3.1 | Typical Sections Analysis | 30d | 2018-10-19 | 2018-11-29 | 86 | 65d |  |  |
| 91 | 3.3.3.2 | Complete Streets/Multi Modal Analysis | 30d | 2018-10-19 | 2018-11-29 | 86 | 65d |  |  |
| 92 | 3.3.3.3 | Concept Development | 40d | 2018-11-23 | 2019-01-17 | 85, 88, 33 | 0d |  |  |
| 93 | 3.3.3.4 | Access Management Analysis | 40d | 2018-11-23 | 2019-01-17 | 88 | 30d |  |  |
| 94 | 3.3.3.5 | Drainage Analysis | 30d | 2019-01-18 | 2019-02-28 | 92 | 0d |  |  |
| 95 | 3.3.3.6 | Utility Coordination & Analysis | 30d | 2019-01-18 | 2019-02-28 | 92 | 0d |  |  |
| 96 | 3.3.3.7 | Railroad Coordination | 30d | 2019-01-18 | 2019-02-28 | 92 | 0d |  |  |
| 97 | 3.3.3.8 | Evaluation Matrix (1st Draft) | 5d | 2019-03-01 | 2019-03-07 | 90, 91, 94, 95, 96, 93, 92 | 0d |  |  |
| 98 | 3.3.3.9 | Construction Cost Estimates (LRE) | 10d | 2019-03-08 | 2019-03-21 | 97 | 20d |  |  |
| 99 | 3.3.3.10 | Right-of-Way Analysis | 20d | 2019-03-08 | 2019-04-04 | 97 | 10d |  |  |
| 100 | 3.3.3.11 | Evaluation Matrix (2nd Draft) | 5d | 2019-04-19 | 2019-04-25 | 98, 99, 112, 113, 114, 115, 116, 117 | 0d |  |  |
| 101 | 3.3.3.12 | Refine Alternatives (based on public input) | 20d | 2019-05-20 | 2019-06-14 | 65 | 210d |  |  |
| 102 | 3.3.3.13 | Prepare 1st DRAFT Engineering Reports (Drainage, Utility, Roadway Plans, ITS, Lighting, Pavement, Geotech, PER) | 30d | 2019-05-20 | 2019-06-28 | 65, 22, 88 | 0d |  |  |
| 103 | 3.3.3.14 | FDOT Review - 1st DRAFT Engineering Reports | 20d | 2019-07-01 | 2019-07-26 | 102 | 0d |  |  |
| 104 | 3.3.3.15 | Update DRAFT Engineering Reports | 15d | 2019-07-29 | 2019-08-16 | 103 | 0d |  |  |
| 105 | 3.3.3.16 | VE Study | 5d | 2019-08-19 | 2019-08-23 | 104 | 0d |  |  |
| 106 | 3.3.3.17 | VE Issues Resolution | 10d | 2019-09-23 | 2019-10-04 | 105FS+20d | 0d |  |  |
| 107 | 3.3.3.18 | Prepare Typical Section Package | 20d | 2019-10-07 | 2019-11-01 | 106 | 16d | 0d |  |
| 108 | 3.3.3.19 | Prepare Design Variations and Exceptions | 20d | 2019-10-07 | 2019-11-01 | 106 | 16d | 0d |  |
| 109 | 3.3.3.20 | Typical Section Selection | 20d | 2019-11-04 | 2019-11-29 | 107, 108 | 16d |  | 759 |
| 110 | 3.3.3.21 | FDOT Review - 2nd DRAFT Engineering Reports (Drainage, Utility, Roadway Plans, ITS, Lighting, Pavement, Geotech, PER) | 20d | 2019-11-04 | 2019-11-29 | 107 | 16d |  |  |

| ID | WBS | Task | Duration | Start | Finish | Predecessors | Total slack | Free slack | PSM Codes |
| --- | --- | --- | --- | --- | --- | --- | --- | --- | --- |
| 111 | 3.4 | **ENVIRONMENTAL ANALYSIS** | 172d | 2019-03-08 | 2019-11-04 |  | 0d |  |  |
| 112 | 3.4.1 | Data Collection & Cultural Resources Assessment Survey | 30d | 2019-03-08 | 2019-04-18 | 97 | 0d |  |  |
| 113 | 3.4.2 | Data Collection & Noise Analysis | 30d | 2019-03-08 | 2019-04-18 | 97 | 0d |  |  |
| 114 | 3.4.3 | Data Collection & Contamination Screen Evaluation | 30d | 2019-03-08 | 2019-04-18 | 97 | 0d |  |  |
| 115 | 3.4.4 | Wetland Delineation and Evaluation | 30d | 2019-03-08 | 2019-04-18 | 97 | 0d |  |  |
| 116 | 3.4.5 | Data Collection & Wildlife Survey | 30d | 2019-03-08 | 2019-04-18 | 97 | 0d |  |  |
| 117 | 3.4.6 | Essential Fish Habitat Evaluation | 30d | 2019-03-08 | 2019-04-18 | 97 | 0d |  |  |
| 118 | 3.4.7 | Determination of Section 4(f) | 15d | 2019-03-08 | 2019-03-28 | 97 | 61d | 0d |  |
| 119 | 3.4.8 | Prepare 1st Draft Natural Resource Evaluation Report | 30d | 2019-04-19 | 2019-05-30 | 115, 116, 117 | 46d | 0d |  |
| 120 | 3.4.9 | Prepare 1st Draft Cultural Resources Assessment Survey | 30d | 2019-04-19 | 2019-05-30 | 112 | 46d | 0d |  |
| 121 | 3.4.10 | Prepare 1st Draft Contamination Screen Evaluation Report | 30d | 2019-04-19 | 2019-05-30 | 114 | 46d | 0d |  |
| 122 | 3.4.11 | Prepare 1st Draft Noise Study Report | 30d | 2019-04-19 | 2019-05-30 | 113 | 46d | 0d |  |
| 123 | 3.4.12 | Prepare Draft Section 4(f) Evaluation | 30d | 2019-03-29 | 2019-05-09 | 118 | 61d | 15d |  |
| 124 | 3.4.13 | FDOT Review 1st DRAFT Environmental Reports (NRE, CSER, CRAS, Noise, Section 4(f)) | 20d | 2019-05-31 | 2019-06-27 | 119, 120, 121, 122, 123 | 46d | 0d |  |
| 125 | 3.4.14 | Update Environmental Reports | 15d | 2019-06-28 | 2019-07-18 | 124 | 46d | 0d |  |
| 126 | 3.4.15 | Finalize Cultural Resources Assessment Survey | 10d | 2019-07-19 | 2019-08-01 | 125 | 46d |  | 333 |
| 127 | 3.4.16 | Finalize Natural Resource Evaluation Report | 10d | 2019-07-19 | 2019-08-01 | 125 | 56d | 46d | 761 |
| 128 | 3.4.17 | Submit CRAS to OEM | 20d | 2019-10-07 | 2019-11-01 | 125, 106, 126 | 0d |  |  |
| 129 | 3.4.18 | SHPO Consultation Complete | 1d | 2019-11-04 | 2019-11-04 | 128 | 0d |  | 762 |
| 130 | 3.4.19 | Submit NRE to USFWS | 1d | 2019-10-07 | 2019-10-07 | 106, 127 | 10d | 0d |  |
| 131 | 3.4.20 | Submit NRE to NMFS | 1d | 2019-10-07 | 2019-10-07 | 106, 127 | 10d | 0d |  |
| 132 | 3.4.21 | Informal USFWS Consultation Complete | 10d | 2019-10-08 | 2019-10-21 | 130 | 10d |  | 752 |
| 133 | 3.4.22 | Informal NMFS Consultation Complete | 10d | 2019-10-08 | 2019-10-21 | 131 | 10d |  | 763 |
| 134 | 3.4.23 | Prepare Conceptual Relocation Plan | 20d | 2019-10-07 | 2019-11-01 | 106 | 1d |  |  |

| ID | WBS | Task | Type | Duration | Start | Finish | Predecessors | Total slack | PSM Codes |
| --- | --- | --- | --- | --- | --- | --- | --- | --- | --- |
| 135 | 3.5 | **FINAL SEIR DOCUMENTS** |  | 109d | 2019-11-05 | 2020-04-03 |  | 0d |  |
| 136 | 3.5.1 | Prepare DRAFT SEIR |  | 20d | 2019-11-05 | 2019-12-02 | 106, 11, 129, 132, 133, 134 | 0d |  |
| 137 | 3.5.2 | FDOT Review DRAFT SEIR |  | 20d | 2019-12-03 | 2019-12-30 | 136 | 0d | 713 |
| 138 | 3.5.3 | Finalize Engineering & Environmental Reports |  | 10d | 2020-01-29 | 2020-02-11 | 74 | 5d | 756 |
| 139 | 3.5.4 | Finalize Section 4(f) Evaluation |  | 5d | 2020-01-29 | 2020-02-04 | 74 | 0d | 751 |
| 140 | 3.5.5 | Finalize Noise Study Report |  | 5d | 2020-01-29 | 2020-02-04 | 74 | 0d | 335 |
| 141 | 3.5.6 | Finalize Preliminary Engineering Report |  | 5d | 2020-01-29 | 2020-02-04 | 74 | 10d | 760 |
| 142 | 3.5.7 | Prepare FINAL SEIR |  | 10d | 2020-02-05 | 2020-02-18 | 74, 139, 140 | 0d |  |
| 143 | 3.5.8 | Submit FINAL SEIR to District OEM |  | 20d | 2020-02-19 | 2020-03-17 | 142, 138, 141 | 0d |  |
| 144 | 3.5.9 | District Secretary Approval of SEIR | milestone | 0d | 2020-03-19 | 2020-03-19 | 143FS+2d | 0d | 722 |
| 145 | 3.5.10 | Pass the Torch Meeting |  | 1d | 2020-04-03 | 2020-04-03 | 144FS+10d | 0d |  |
